# Timing stampi coperchio

Schedule from MS Project, 2003-10-30 to 2004-07-02.
Merloni Elettrodomestici

## Calendars

- Standard: Mon-Fri 08:00-12:00, 13:00-17:00; Sat-Sun off.

## Resources

| Resource |
| --- |
| Fornitore |
| Merloni |
| Team |
| Fornitori |

## Schedule

| ID | WBS | Task | Type | Duration | Start | Finish | Predecessors | Total slack | Free slack | Constraint | Resources | Work |
| --- | --- | --- | --- | --- | --- | --- | --- | --- | --- | --- | --- | --- |
| 1 | 1 | Coperchio TL |  | 1d? | 2003-10-30 | 2003-10-30 |  | 175d |  |  |  |  |
| 2 | 2 | **Fase1: Apertura contatti con I Fornitori** |  | 1d | 2003-10-30 | 2003-10-30 |  | 98.5d |  |  |  | 8h |
| 3 | 2.1 | Accettazione offerta e definizione tempistiche | milestone | 1d | 2003-10-30 | 2003-10-30 |  | 98.5d | 0d |  | Merloni | 8h |
| 4 | 3 | **Fase2: Definizioni dettagli e selezione Fornitore** |  | 8.5d | 2003-10-31 | 2003-11-12 |  | 134.5d |  |  |  | 216h |
| 5 | 3.1 | Condivisione soluzioni tecniche con il fornitore |  | 1w | 2003-10-31 | 2003-11-06 | 3 | 170d |  |  | Fornitore; Merloni | 80h |
| 6 | 3.2 | Analisi disegni e impostazione progetto stampi |  | 1.5w | 2003-10-31 | 2003-11-11 | 3 | 97.5d | 0d |  | Fornitore | 60h |
| 7 | 3.3 | Definiizone piano sviluppo attrezzature |  | 1.5w | 2003-10-31 | 2003-11-11 | 3 | 125.5d | 0d |  | Fornitore | 60h |
| 8 | 3.4 | Condivisione timing sviluppo attrezzature |  | 1d | 2003-11-11 | 2003-11-12 | 7 | 125.5d | 0d |  | Fornitore; Merloni | 16h |
| 9 | 4 | **Fase3: Congelamento Disegni** |  | 41d | 2003-11-12 | 2004-01-08 |  | 126.5d |  |  |  |  |
| 10 | 4.1 | Realizzazione attrezzature prototipali |  | 8w | 2003-11-12 | 2004-01-07 | 8 | 126.5d | 0d |  |  |  |
| 11 | 4.2 | Consegna prototipi | milestone | 1d | 2004-01-07 | 2004-01-08 | 10 | 126.5d |  |  |  |  |
| 12 | 5 | **Fase4: Progettazione** |  | 26d | 2003-11-11 | 2003-12-17 |  | 98.5d |  |  |  | 296h |
| 13 | 5.1 | Progettazione stampo |  | 5w | 2003-11-11 | 2003-12-16 | 6 | 118.5d | 0d |  | Fornitore | 200h |
| 14 | 5.2 | Approvigionamento materiali |  | 2w | 2003-11-11 | 2003-11-25 | 6 | 98.5d | 0d |  | Fornitore | 80h |
| 15 | 5.3 | Checkpoint 4 |  | 1d | 2003-12-16 | 2003-12-17 | 13, 14 | 142.5d |  |  | Fornitore; Merloni | 16h |
| 16 | 6 | **Fase5: Costruzione** |  | 69.5d | 2003-11-25 | 2004-03-01 |  | 89d |  |  |  | 8h |
| 17 | 6.1 | Lavorazione stampi |  | 12w | 2003-11-25 | 2004-02-17 | 14 | 98.5d |  |  |  |  |
| 18 | 6.2 | Realizzazione moduli imbutitura |  | 5w | 2003-12-16 | 2004-01-20 | 13 | 118.5d | 0d |  |  |  |
| 19 | 6.3 | Consegna prototipi per HT | milestone | 0d | 2004-01-20 | 2004-01-20 | 18 | 118.5d |  |  |  |  |
| 20 | 6.4 | Assemblaggio |  | 4w | 2004-02-02 | 2004-02-27 |  | 55d | 0d | start no earlier than 2004-02-02 |  |  |
| 21 | 6.5 | Prima campionatura | milestone | 1d | 2004-03-01 | 2004-03-01 | 20 | 59d | 0d |  | Fornitore | 8h |
| 22 | 7 | **Fase6** |  | 35d | 2004-03-01 | 2004-04-16 |  | 55d |  |  |  | 960h |
| 23 | 7.1 | Verifiche dimensionali e funzionali |  | 6w | 2004-03-02 | 2004-04-12 | 21 | 59d |  |  | Merloni; Fornitore | 480h |
| 24 | 7.2 | Progettazione automazione trasfer |  | 5w | 2004-03-01 | 2004-04-02 | 20 | 65d |  |  | Fornitore | 200h |
| 25 | 7.3 | Messa a punto stampi / transfer |  | 5w | 2004-03-01 | 2004-04-02 | 20 | 55d | 0d |  | Fornitore | 200h |
| 26 | 7.4 | Collaudo |  | 1w | 2004-04-05 | 2004-04-09 | 25 | 55d | 0d |  | Fornitore | 40h |
| 27 | 7.5 | Benestare dimensionale e funzionale |  | 1w | 2004-04-12 | 2004-04-16 | 26 | 55d | 0d |  | Merloni | 40h |
| 28 | 7.6 | Checkpoint7 | milestone | 0d | 2004-04-16 | 2004-04-16 | 27 | 55d |  |  |  |  |
| 30 | 8 | Flangie e Bocche |  | 1d? | 2003-10-30 | 2003-10-30 |  | 212d |  |  |  |  |

| ID | WBS | Task | Type | Duration | Start | Finish | Predecessors | Total slack | Free slack | Resources | Work |
| --- | --- | --- | --- | --- | --- | --- | --- | --- | --- | --- | --- |
| 31 | 9 | **Fase1: Apertura contatti con I Fornitori** |  | 5d | 2003-10-30 | 2003-11-05 |  | 10d |  |  | 40h |
| 32 | 9.1 | Presentazione disegno e richiesta offerte | milestone | 0d | 2003-10-30 | 2003-10-30 |  | 10d | 0d | Merloni |  |
| 33 | 9.2 | Presentazione offerte |  | 1w | 2003-10-30 | 2003-11-05 | 32 | 10d | 0d | Fornitori | 40h |
| 34 | 9.3 | Checkpoint1 | milestone | 0d | 2003-11-05 | 2003-11-05 | 33 | 10d | 0d | Team |  |
| 35 | 10 | **Fase2: Definizioni dettagli e selezione Fornitore** |  | 10d | 2003-11-06 | 2003-11-19 |  | 10d |  |  | 120h |
| 36 | 10.1 | Definizione piano di lavoro |  | 1w | 2003-11-06 | 2003-11-12 | 34 | 167d |  | Merloni | 40h |
| 37 | 10.2 | Analisi offerte |  | 2w | 2003-11-06 | 2003-11-19 | 33, 34 | 10d | 0d | Merloni | 80h |
| 38 | 10.3 | Accettazione offerta | milestone | 0d | 2003-11-19 | 2003-11-19 | 37 | 10d | 0d | Merloni |  |
| 39 | 10.4 | Checkpoint2 | milestone | 0d | 2003-11-19 | 2003-11-19 | 34, 38 | 10d | 0d | Team |  |
| 40 | 11 | **Fase3: Congelamento Disegni** |  | 5d | 2003-11-20 | 2003-11-26 |  | 10d |  |  | 40h |
| 41 | 11.1 | Congelamento Disegni |  | 1w | 2003-11-20 | 2003-11-26 | 38, 39 | 10d | 0d | Merloni | 40h |
| 42 | 12 | Approvigionamenti materiali |  | 3w | 2003-11-20 | 2003-12-10 | 38, 39 | 183d |  | Fornitore | 120h |
| 43 | 13 | **Fase4: Progettazione** |  | 40d | 2003-11-26 | 2004-01-21 |  | 10d |  |  | 320h |
| 44 | 13.1 | Progettazione |  | 8w | 2003-11-27 | 2004-01-21 | 41 | 10d | 0d | Fornitore | 320h |
| 45 | 13.2 | checkpoint5 | milestone | 0d | 2003-11-26 | 2003-11-26 | 41 | 157d |  | Team |  |
| 46 | 14 | **Fase5: Costruzione** |  | 101d | 2003-12-25 | 2004-05-13 |  | 10d |  |  | 808h |
| 47 | 14.1 | Lavorazione |  | 16w | 2003-12-25 | 2004-04-14 | 44SS+4w | 10d | 0d | Fornitore | 640h |
| 48 | 14.2 | Assemblaggio Stampi |  | 4w | 2004-04-15 | 2004-05-12 | 47 | 10d | 0d | Fornitore | 160h |
| 49 | 14.3 | Prima campionatura |  | 1d | 2004-05-13 | 2004-05-13 | 48 | 10d | 0d | Fornitore | 8h |
| 50 | 14.4 | Checkpoint6 | milestone | 0d | 2004-05-13 | 2004-05-13 | 49 | 36d |  | Team |  |
| 51 | 15 | **Fase6: Benestare** |  | 26d | 2004-05-14 | 2004-06-18 |  | 10d |  |  | 328h |
| 52 | 15.1 | Verifica dimensionale, funzionale e di montaggio |  | 1w | 2004-05-14 | 2004-05-20 | 49 | 10d | 0d | Fornitore | 40h |
| 53 | 15.2 | Messa a punto |  | 2w | 2004-05-21 | 2004-06-03 | 52 | 10d | 0d | Fornitore | 80h |
| 54 | 15.3 | Trattamenti |  | 2w | 2004-05-21 | 2004-06-03 | 52 | 10d | 0d | Fornitore | 80h |
| 55 | 15.4 | Nuovo collaudo |  | 1d | 2004-06-04 | 2004-06-04 | 53, 54 | 10d | 0d | Fornitore | 8h |
| 56 | 15.5 | Verifica dimensionale e funzionale |  | 1w | 2004-06-07 | 2004-06-11 | 55 | 10d | 0d | Merloni | 40h |
| 57 | 15.6 | Benestare dimensionale e funzionale |  | 1w | 2004-06-14 | 2004-06-18 | 56 | 10d |  | Merloni | 40h |
| 58 | 15.7 | Completamento stampo |  | 1w | 2004-06-07 | 2004-06-11 | 55 | 15d |  | Fornitore | 40h |
| 60 | 16 | Mobile U |  | 1d? | 2003-10-30 | 2003-10-30 |  | 212d |  |  |  |

| ID | WBS | Task | Type | Duration | Start | Finish | Predecessors | Total slack | Free slack | Resources | Work |
| --- | --- | --- | --- | --- | --- | --- | --- | --- | --- | --- | --- |
| 61 | 17 | **Fase1: Apertura contatti con I Fornitori** |  | 6d | 2003-10-30 | 2003-11-06 |  | 0d |  |  | 48h |
| 62 | 17.1 | Presentazione disegno e richiesta offerte | milestone | 0d | 2003-10-30 | 2003-10-30 |  | 0d |  | Merloni |  |
| 63 | 17.2 | Presentazione offerte |  | 1w | 2003-10-30 | 2003-11-05 | 62 | 0d |  | Fornitori | 40h |
| 64 | 17.3 | Checkpoint1 |  | 1d | 2003-11-06 | 2003-11-06 | 63 | 0d |  | Team | 8h |
| 65 | 18 | **Fase2: Definizioni dettagli e selezione Fornitore** |  | 10d | 2003-11-07 | 2003-11-20 |  | 0d |  |  | 120h |
| 66 | 18.1 | Definizione piano di lavoro |  | 1w | 2003-11-07 | 2003-11-13 | 64 | 166d |  | Merloni | 40h |
| 67 | 18.2 | Analisi offerte |  | 2w | 2003-11-07 | 2003-11-20 | 63, 64 | 0d |  | Merloni | 80h |
| 68 | 18.3 | Accettazione offerta | milestone | 0d | 2003-11-20 | 2003-11-20 | 67 | 0d |  | Merloni |  |
| 69 | 18.4 | Checkpoint2 | milestone | 0d | 2003-11-20 | 2003-11-20 | 64, 68 | 0d |  | Team |  |
| 70 | 19 | **Fase3: Congelamento Disegni** |  | 5d | 2003-11-21 | 2003-11-27 |  | 0d |  |  | 40h |
| 71 | 19.1 | Congelamento Disegni |  | 1w | 2003-11-21 | 2003-11-27 | 68, 69 | 0d |  | Merloni | 40h |
| 72 | 20 | Approvigionamenti materiali |  | 3w | 2003-11-21 | 2003-12-11 | 68, 69 | 146d |  | Fornitore | 120h |
| 73 | 21 | **Fase4: Progettazione** |  | 115d | 2003-11-28 | 2004-05-06 |  | 0d |  |  | 920h |
| 74 | 21.1 | Progettazione |  | 14w | 2003-11-28 | 2004-03-04 | 71 | 0d |  | Fornitore | 560h |
| 75 | 21.2 | Valutazione dell'opportunità di Analisi Sperimentali anche a mezzo di prototipi |  | 1w | 2004-03-05 | 2004-03-11 | 74 | 41d | 0d | Merloni | 40h |
| 76 | 21.3 | Realizzazioni analisi e prototipi |  | 8w | 2004-03-12 | 2004-05-06 | 75 | 41d | 0d | Fornitore | 320h |
| 77 | 21.4 | checkpoint5 | milestone | 0d | 2004-05-06 | 2004-05-06 | 76 | 41d |  | Team |  |
| 78 | 22 | **Fase5: Costruzione** |  | 91d | 2003-12-26 | 2004-04-30 |  | 0d |  |  | 1208h |
| 79 | 22.1 | Lavorazione |  | 16w | 2003-12-26 | 2004-04-15 | 74SS+4w | 0d |  | Fornitore | 640h |
| 80 | 22.2 | Assemblaggio Stampi |  | 14w | 2004-01-23 | 2004-04-29 | 79SS+4w | 0d |  | Fornitore | 560h |
| 81 | 22.3 | Prima campionatura |  | 1d | 2004-04-30 | 2004-04-30 | 80 | 0d |  | Fornitore | 8h |
| 82 | 22.4 | Checkpoint6 | milestone | 0d | 2004-04-30 | 2004-04-30 | 81 | 45d |  | Team |  |
| 83 | 23 | **Fase6: Benestare** |  | 45d | 2004-05-03 | 2004-07-02 |  | 0d |  |  | 600h |
| 84 | 23.1 | Verifica dimensionale, funzionale e di montaggio |  | 1w | 2004-05-03 | 2004-05-07 | 81 | 0d |  | Fornitore | 40h |
| 85 | 23.2 | Messa a punto |  | 5w | 2004-05-10 | 2004-06-11 | 84 | 0d |  | Fornitore | 200h |
| 86 | 23.3 | Trattamenti |  | 5w | 2004-05-10 | 2004-06-11 | 84 | 0d |  | Fornitore | 200h |
| 87 | 23.4 | Nuovo collaudo |  | 1w | 2004-06-14 | 2004-06-18 | 85, 86 | 0d |  | Fornitore | 40h |
| 88 | 23.5 | Verifica dimensionale e funzionale |  | 1w | 2004-06-21 | 2004-06-25 | 87 | 0d |  | Merloni | 40h |
| 89 | 23.6 | Benestare dimensionale e funzionale |  | 1w | 2004-06-28 | 2004-07-02 | 88 | 0d |  | Merloni | 40h |
| 90 | 23.7 | Completamento stampo |  | 1w | 2004-06-21 | 2004-06-25 | 87 | 5d |  | Fornitore | 40h |
| 92 | 24 | Pannello Front |  | 1d? | 2003-10-30 | 2003-10-30 |  | 212d |  |  |  |

| ID | WBS | Task | Type | Duration | Start | Finish | Predecessors | Total slack | Free slack | Resources | Work |
| --- | --- | --- | --- | --- | --- | --- | --- | --- | --- | --- | --- |
| 93 | 25 | **Fase1: Apertura contatti con I Fornitori** |  | 5d | 2003-10-30 | 2003-11-05 |  | 17d |  |  | 40h |
| 94 | 25.1 | Presentazione disegno e richiesta offerte | milestone | 0d | 2003-10-30 | 2003-10-30 |  | 17d | 0d | Merloni |  |
| 95 | 25.2 | Presentazione offerte |  | 1w | 2003-10-30 | 2003-11-05 | 94 | 17d | 0d | Fornitori | 40h |
| 96 | 25.3 | Checkpoint1 | milestone | 0d | 2003-11-05 | 2003-11-05 | 95 | 17d | 0d | Team |  |
| 97 | 26 | **Fase2: Definizioni dettagli e selezione Fornitore** |  | 10d | 2003-11-06 | 2003-11-19 |  | 17d |  |  | 120h |
| 98 | 26.1 | Definizione piano di lavoro |  | 1w | 2003-11-06 | 2003-11-12 | 96 | 167d |  | Merloni | 40h |
| 99 | 26.2 | Analisi offerte |  | 2w | 2003-11-06 | 2003-11-19 | 95, 96 | 17d | 0d | Merloni | 80h |
| 100 | 26.3 | Accettazione offerta | milestone | 0d | 2003-11-19 | 2003-11-19 | 99 | 17d | 0d | Merloni |  |
| 101 | 26.4 | Checkpoint2 | milestone | 0d | 2003-11-19 | 2003-11-19 | 96, 100 | 17d | 0d | Team |  |
| 102 | 27 | **Fase3: Congelamento Disegni** |  | 5d | 2003-11-20 | 2003-11-26 |  | 17d |  |  | 40h |
| 103 | 27.1 | Congelamento Disegni |  | 1w | 2003-11-20 | 2003-11-26 | 100, 101 | 17d | 0d | Merloni | 40h |
| 104 | 28 | Approvigionamenti materiali |  | 3w | 2003-11-20 | 2003-12-10 | 100, 101 | 183d |  | Fornitore | 120h |
| 105 | 29 | **Fase4: Progettazione** |  | 70d | 2003-11-27 | 2004-03-03 |  | 17d |  |  | 920h |
| 106 | 29.1 | Progettazione |  | 14w | 2003-11-27 | 2004-03-03 | 103 | 17d | 0d | Fornitore | 560h |
| 107 | 29.2 | Valutazione dell'opportunità di Analisi Sperimentali anche a mezzo di prototipi |  | 1w | 2003-11-27 | 2003-12-03 | 103 | 112d | 0d | Merloni | 40h |
| 108 | 29.3 | Realizzazioni analisi e prototipi |  | 8w | 2003-12-04 | 2004-01-28 | 107 | 112d | 0d | Fornitore | 320h |
| 109 | 29.4 | checkpoint5 | milestone | 0d | 2004-01-28 | 2004-01-28 | 108 | 112d |  | Team |  |
| 110 | 30 | **Fase5: Costruzione** |  | 75d | 2003-12-25 | 2004-04-07 |  | 17d |  |  | 680h |
| 111 | 30.1 | Lavorazione |  | 12w | 2003-12-25 | 2004-03-17 | 106SS+4w | 17d | 0d | Fornitore | 480h |
| 112 | 30.2 | Assemblaggio Stampi |  | 4w | 2004-03-04 | 2004-03-31 | 111SS+10w | 17d | 0d | Fornitore | 160h |
| 113 | 30.3 | Prima campionatura |  | 1w | 2004-04-01 | 2004-04-07 | 112 | 17d | 0d | Fornitore | 40h |
| 114 | 30.4 | Checkpoint6 | milestone | 0d | 2004-04-07 | 2004-04-07 | 113 | 62d |  | Team |  |
| 115 | 31 | **Fase6: Benestare** |  | 45d | 2004-04-08 | 2004-06-09 |  | 17d |  |  | 800h |
| 116 | 31.1 | Verifica dimensionale, funzionale e di montaggio |  | 1w | 2004-04-08 | 2004-04-14 | 113 | 17d | 0d | Fornitore | 40h |
| 117 | 31.2 | Realizzazione Primo stampo: Sviluppo Tranciato |  | 5w | 2004-04-15 | 2004-05-19 | 116 | 17d | 0d | Fornitore | 200h |
| 118 | 31.3 | Messa a punto |  | 5w | 2004-04-15 | 2004-05-19 | 116 | 17d | 0d | Fornitore | 200h |
| 119 | 31.4 | Trattamenti |  | 5w | 2004-04-15 | 2004-05-19 | 116 | 17d | 0d | Fornitore | 200h |
| 120 | 31.5 | Nuovo collaudo |  | 1w | 2004-05-20 | 2004-05-26 | 117, 118, 119 | 17d | 0d | Fornitore | 40h |
| 121 | 31.6 | Verifica dimensionale e funzionale |  | 1w | 2004-05-27 | 2004-06-02 | 120 | 17d | 0d | Merloni | 40h |
| 122 | 31.7 | Benestare dimensionale e funzionale |  | 1w | 2004-06-03 | 2004-06-09 | 121 | 17d |  | Merloni | 40h |
| 123 | 31.8 | Completamento stampo |  | 1w | 2004-05-27 | 2004-06-02 | 120 | 22d |  | Fornitore | 40h |

Notes:
- 117: Il primo stampo viene inizialmente sostituito nel processo tramite un taglio al laser del coil, viene realizzato per ultimo perchè, dando i riferimenti su cui si basano gli stampi a seguire, deve essere adattato alla messa a punto di quelli a valle. Questo avviene solo nel caso si stia utilizzando un processo Miramondi, cioè Tranciatura piegatura e poi imbutitura.
