# Gomme

Schedule from MS Project, 2004-01-01 to 2004-06-23.
Merloni Elettrodomestici

## Calendars

- Standard: Mon-Fri 08:00-12:00, 13:00-17:00; Sat-Sun off.

## Resources

| Resource | Cost per use |
| --- | --- |
| Fornitore | 300 |
| Merloni |  |
| Team |  |
| Fornitori |  |

## Schedule

| ID | WBS | Task | Type | Duration | Start | Finish | Predecessors | Total slack | Free slack | Resources | Work |
| --- | --- | --- | --- | --- | --- | --- | --- | --- | --- | --- | --- |
| 1 | 1 | Guarnizioni Gomma 1 Figura |  | 1d? | 2004-01-01 | 2004-01-01 |  | 124d |  |  |  |
| 2 | 2 | Selezione Fornitori |  | 1w | 2004-01-01 | 2004-01-07 |  | 25d | 0d |  |  |
| 3 | 3 | **Fase1: Apertura contatti con I fornitori** |  | 6d | 2004-01-08 | 2004-01-15 | 2 | 25d |  |  | 48h |
| 4 | 3.1 | Presentazione disegno e richiesta di ipotesi di caratteristiche tecniche, lay-out e costo stampo |  | 1d | 2004-01-08 | 2004-01-08 | 2 | 25d | 0d | Merloni | 8h |
| 5 | 3.2 | Presentazione offerte con scheda stampo |  | 1w | 2004-01-09 | 2004-01-15 | 4 | 25d | 0d | Fornitori | 40h |
| 6 | 3.3 | Checkpoint1 | milestone | 0d | 2004-01-15 | 2004-01-15 | 5 | 25d | 0d | Team |  |
| 7 | 4 | **Fase2:Definizione dettaglie e selezione fornitori** |  | 6d | 2004-01-16 | 2004-01-23 |  | 25d |  |  | 88h |
| 8 | 4.1 | Analisi e selezione tra I lay-out proposti |  | 1w | 2004-01-16 | 2004-01-22 | 5, 6 | 25d | 0d | Merloni | 40h |
| 9 | 4.2 | Accettazione offerta |  | 1d | 2004-01-23 | 2004-01-23 | 8 | 25d | 0d | Merloni | 8h |
| 10 | 4.3 | Definizione completa delle specifiche del componente nei suoi dettagli |  | 1w | 2004-01-16 | 2004-01-22 | 4, 6 | 109d |  | Merloni | 40h |
| 11 | 4.4 | Checkpoint2 | milestone | 0d | 2004-01-23 | 2004-01-23 | 9, 6 | 25d | 0d | Team |  |
| 12 | 5 | **Fase4: Progettazione** |  | 30d | 2004-01-26 | 2004-03-05 |  | 25d |  |  | 320h |
| 13 | 5.1 | Definizione soluzioni definitive e dimensionamenti |  | 2w | 2004-01-26 | 2004-02-06 | 11 | 25d | 0d | Fornitore | 80h |
| 14 | 5.2 | Approvigionamenti materiali |  | 2w | 2004-02-09 | 2004-02-20 | 13 | 35d | 10d | Merloni | 80h |
| 15 | 5.3 | Progettazione Stampi |  | 4w | 2004-02-09 | 2004-03-05 | 13 | 25d | 0d | Fornitore | 160h |
| 16 | 5.4 | Checkpoint 4 | milestone | 0d | 2004-03-05 | 2004-03-05 | 15, 14 | 78d |  | Team |  |
| 17 | 6 | **Fase5:Testing** |  | 15d | 2004-03-08 | 2004-03-26 |  | 63d |  |  | 200h |
| 18 | 6.1 | Valutazione dell'opportunità di Analisi Sperimentali anche a mezzo di prototipi |  | 1w | 2004-03-08 | 2004-03-12 | 15 | 63d | 0d | Merloni | 40h |
| 19 | 6.2 | Realizzazioni prototip e analisi |  | 10d | 2004-03-15 | 2004-03-26 | 18 | 63d |  | Fornitore; Merloni | 160h |
| 20 | 6.3 | checkpoint5 | milestone | 0d | 2004-03-12 | 2004-03-12 | 18 | 73d |  | Team |  |
| 21 | 7 | **Fase6:Costruzione** |  | 36d | 2004-03-08 | 2004-04-26 |  | 25d |  |  | 288h |
| 22 | 7.1 | Costruzione stampi |  | 7w | 2004-03-08 | 2004-04-23 | 14, 15 | 25d | 0d | Fornitore | 280h |
| 23 | 7.2 | Prima campionatura |  | 1d | 2004-04-26 | 2004-04-26 | 22 | 25d | 0d | Fornitore | 8h |
| 24 | 7.3 | Checkpoint6 | milestone | 0d | 2004-04-26 | 2004-04-26 | 23 | 42d |  | Team |  |

| ID | WBS | Task | Type | Duration | Start | Finish | Predecessors | Total slack | Free slack | Resources | Work |
| --- | --- | --- | --- | --- | --- | --- | --- | --- | --- | --- | --- |
| 25 | 8 | **Fase7: Benestare** |  | 17d | 2004-04-27 | 2004-05-19 | 23 | 25d |  |  | 216h |
| 26 | 8.1 | Verifica dimensionale e funzionale |  | 1w | 2004-04-27 | 2004-05-03 | 23 | 25d | 0d | Merloni; Fornitore | 80h |
| 27 | 8.2 | Prima messa a punto degli stampi |  | 1w | 2004-05-04 | 2004-05-10 | 26 | 25d | 0d | Fornitore; Merloni | 80h |
| 28 | 8.3 | Nuovo collaudo |  | 1d | 2004-05-11 | 2004-05-11 | 27 | 25d | 0d | Fornitore | 8h |
| 29 | 8.4 | Rilievo non conformità |  | 1w | 2004-05-12 | 2004-05-18 | 28 | 25d | 0d | Merloni | 40h |
| 30 | 8.5 | Benestare dimensionale e funzionale |  | 1d | 2004-05-19 | 2004-05-19 | 29 | 25d | 0d | Merloni | 8h |
| 31 | 8.6 | Checkpoint7 | milestone | 0d | 2004-05-19 | 2004-05-19 | 30 | 25d |  |  |  |
| 33 | 9 | Tubo OKO Gomma 6 Figure |  | 1d? | 2004-01-01 | 2004-01-01 |  | 124d |  |  |  |
| 34 | 10 | Selezione Fornitori |  | 1w | 2004-01-01 | 2004-01-07 |  | 0d |  |  |  |
| 35 | 11 | **Fase1: Apertura contatti con I fornitori** |  | 6d | 2004-01-08 | 2004-01-15 | 34 | 0d |  |  | 48h |
| 36 | 11.1 | Presentazione disegno e richiesta di ipotesi di caratteristiche tecniche, lay-out e costo stampo |  | 1d | 2004-01-08 | 2004-01-08 | 34 | 0d |  | Merloni | 8h |
| 37 | 11.2 | Presentazione offerte con scheda stampo |  | 1w | 2004-01-09 | 2004-01-15 | 36 | 0d |  | Fornitori | 40h |
| 38 | 11.3 | Checkpoint1 | milestone | 0d | 2004-01-15 | 2004-01-15 | 37 | 0d |  | Team |  |
| 39 | 12 | **Fase2:Definizione dettaglie e selezione fornitori** |  | 6d | 2004-01-16 | 2004-01-23 |  | 0d |  |  | 88h |
| 40 | 12.1 | Analisi e selezione tra I lay-out proposti |  | 1w | 2004-01-16 | 2004-01-22 | 37, 38 | 0d |  | Merloni | 40h |
| 41 | 12.2 | Accettazione offerta |  | 1d | 2004-01-23 | 2004-01-23 | 40 | 0d |  | Merloni | 8h |
| 42 | 12.3 | Definizione completa delle specifiche del componente nei suoi dettagli |  | 1w | 2004-01-16 | 2004-01-22 | 36, 38 | 109d |  | Merloni | 40h |
| 43 | 12.4 | Checkpoint2 | milestone | 0d | 2004-01-23 | 2004-01-23 | 38, 41 | 0d |  | Team |  |
| 44 | 13 | **Fase4: Progettazione** |  | 45d | 2004-01-26 | 2004-03-26 |  | 0d |  |  | 480h |
| 45 | 13.1 | Definizione soluzioni definitive e dimensionamenti |  | 3w | 2004-01-26 | 2004-02-13 | 43 | 0d |  | Fornitore | 120h |
| 46 | 13.2 | Approvigionamenti materiali |  | 3w | 2004-02-16 | 2004-03-05 | 45 | 15d |  | Merloni | 120h |
| 47 | 13.3 | Progettazione Stampi |  | 6w | 2004-02-16 | 2004-03-26 | 45 | 0d |  | Fornitore | 240h |
| 48 | 13.4 | Checkpoint 4 | milestone | 0d | 2004-03-26 | 2004-03-26 | 46, 47 | 63d |  | Team |  |
| 49 | 14 | **Fase5:Testing** |  | 15d | 2004-03-29 | 2004-04-16 |  | 48d |  |  | 200h |
| 50 | 14.1 | Valutazione dell'opportunità di Analisi Sperimentali anche a mezzo di prototipi |  | 1w | 2004-03-29 | 2004-04-02 | 47 | 48d | 0d | Merloni | 40h |
| 51 | 14.2 | Realizzazioni prototip e analisi |  | 10d | 2004-04-05 | 2004-04-16 | 50 | 48d |  | Fornitore; Merloni | 160h |
| 52 | 14.3 | checkpoint5 | milestone | 0d | 2004-04-02 | 2004-04-02 | 50 | 58d |  | Team |  |

| ID | WBS | Task | Type | Duration | Start | Finish | Predecessors | Total slack | Resources | Work |
| --- | --- | --- | --- | --- | --- | --- | --- | --- | --- | --- |
| 53 | 15 | **Fase6:Costruzione** |  | 46d | 2004-03-29 | 2004-05-31 |  | 0d |  | 368h |
| 54 | 15.1 | Costruzione stampi |  | 9w | 2004-03-29 | 2004-05-28 | 46, 47 | 0d | Fornitore | 360h |
| 55 | 15.2 | Prima campionatura |  | 1d | 2004-05-31 | 2004-05-31 | 54 | 0d | Fornitore | 8h |
| 56 | 15.3 | Checkpoint6 | milestone | 0d | 2004-05-31 | 2004-05-31 | 55 | 17d | Team |  |
| 57 | 16 | **Fase7: Benestare** |  | 17d | 2004-06-01 | 2004-06-23 |  | 0d |  | 216h |
| 58 | 16.1 | Verifica dimensionale e funzionale |  | 1w | 2004-06-01 | 2004-06-07 | 55 | 0d | Merloni; Fornitore | 80h |
| 59 | 16.2 | Prima messa a punto degli stampi |  | 1w | 2004-06-08 | 2004-06-14 | 58 | 0d | Fornitore; Merloni | 80h |
| 60 | 16.3 | Nuovo collaudo |  | 1d | 2004-06-15 | 2004-06-15 | 59 | 0d | Fornitore | 8h |
| 61 | 16.4 | Rilievo non conformità |  | 1w | 2004-06-16 | 2004-06-22 | 60 | 0d | Merloni | 40h |
| 62 | 16.5 | Benestare dimensionale e funzionale |  | 1d | 2004-06-23 | 2004-06-23 | 61 | 0d | Merloni | 8h |
| 63 | 16.6 | Checkpoint7 | milestone | 0d | 2004-06-23 | 2004-06-23 | 62 | 0d |  |  |
