# Estetiche

Schedule from MS Project, 2004-01-01 to 2004-07-19.
Merloni Elettrodomestici

## Calendars

- Standard: Mon-Fri 08:00-12:00, 13:00-17:00; Sat-Sun off.

## Resources

| Resource |
| --- |
| Fornitore |
| Merloni |
| Team |
| Fornitori |

## Schedule

| ID | WBS | Task | Type | Duration | Start | Finish | Predecessors | Total slack | Free slack | Resources | Work |
| --- | --- | --- | --- | --- | --- | --- | --- | --- | --- | --- | --- |
| 1 | 1 | Cornici Top |  | 1d? | 2004-01-01 | 2004-01-01 |  | 142d |  |  |  |
| 2 | 2 | **Fase1: Apertura contatti con I Fornitori** |  | 5d | 2004-01-01 | 2004-01-07 |  | 2d |  |  | 40h |
| 3 | 2.1 | Presentazione disegno e richiesta offerte | milestone | 0d | 2004-01-01 | 2004-01-01 |  | 2d | 0d | Merloni |  |
| 4 | 2.2 | Presentazione offerte |  | 1w | 2004-01-01 | 2004-01-07 | 3 | 2d | 0d | Fornitori | 40h |
| 5 | 2.3 | Checkpoint1 | milestone | 0d | 2004-01-07 | 2004-01-07 | 4 | 2d | 0d | Team |  |
| 6 | 3 | **Fase2: Definizioni dettagli e selezione Fornitore** |  | 10d | 2004-01-08 | 2004-01-21 |  | 2d |  |  | 120h |
| 7 | 3.1 | Definizione piano di lavoro |  | 1w | 2004-01-08 | 2004-01-14 | 5 | 133d |  | Merloni | 40h |
| 8 | 3.2 | Analisi offerte |  | 2w | 2004-01-08 | 2004-01-21 | 4, 5 | 2d | 0d | Merloni | 80h |
| 9 | 3.3 | Accettazione offerta | milestone | 0d | 2004-01-21 | 2004-01-21 | 8 | 2d | 0d | Merloni |  |
| 10 | 3.4 | Checkpoint2 | milestone | 0d | 2004-01-21 | 2004-01-21 | 9, 5 | 2d | 0d | Team |  |
| 11 | 4 | **Fase3: Codesign** |  | 20d | 2004-01-22 | 2004-02-18 |  | 2d |  |  | 240h |
| 12 | 4.1 | Consegna Pelle 3D |  | 1w | 2004-01-22 | 2004-01-28 | 9, 10 | 2d | 0d | Merloni | 40h |
| 13 | 4.2 | Codesign |  | 2w | 2004-01-29 | 2004-02-11 | 12 | 2d | 0d | Fornitore; Merloni | 160h |
| 14 | 4.3 | Release al Codesign |  | 1w | 2004-02-12 | 2004-02-18 | 13 | 2d | 0d | Merloni | 40h |
| 15 | 4.4 | Checkpoint 3 | milestone | 0d | 2004-02-18 | 2004-02-18 | 14 | 2d | 0d | Team |  |
| 16 | 5 | Approvigionamenti materiali |  | 3w | 2004-01-22 | 2004-02-11 | 10, 9 | 113d |  | Fornitore | 120h |
| 17 | 6 | **Fase4: Progettazione** |  | 25d | 2004-02-19 | 2004-03-24 |  | 2d |  |  | 280h |
| 18 | 6.1 | Progettazione di massima |  | 2w | 2004-02-19 | 2004-03-03 | 15 | 2d | 0d | Fornitore | 80h |
| 19 | 6.2 | Progettazione dettagli |  | 3w | 2004-02-19 | 2004-03-10 | 15 | 83d | 0d | Fornitore | 120h |
| 20 | 6.3 | Valutazione dell'opportunità di Analisi Sperimentali anche a mezzo di prototipi |  | 1w | 2004-03-11 | 2004-03-17 | 19 | 83d | 0d | Merloni | 40h |
| 21 | 6.4 | Realizzazioni analisi e prototipi |  | 1w | 2004-03-18 | 2004-03-24 | 20 | 83d |  | Fornitore | 40h |
| 22 | 6.5 | checkpoint5 | milestone | 0d | 2004-03-17 | 2004-03-17 | 19, 20 | 88d |  | Team |  |
| 23 | 7 | **Fase5: Costruzione** |  | 60d | 2004-03-04 | 2004-05-26 |  | 2d |  |  | 600h |
| 24 | 7.1 | Lavorazione portastampi |  | 3w | 2004-03-04 | 2004-03-24 | 18 | 32d | 30d | Fornitore | 120h |
| 25 | 7.2 | Lavorazione parti stampanti |  | 9w | 2004-03-04 | 2004-05-05 | 18 | 2d | 0d | Fornitore | 360h |
| 26 | 7.3 | Assemblaggio Stampi |  | 2w | 2004-05-06 | 2004-05-19 | 24, 25 | 2d | 0d | Fornitore | 80h |
| 27 | 7.4 | Prima campionatura |  | 1w | 2004-05-20 | 2004-05-26 | 26 | 2d | 0d | Fornitore | 40h |
| 28 | 7.5 | Checkpoint6 | milestone | 0d | 2004-05-26 | 2004-05-26 | 27 | 38d |  | Team |  |

| ID | WBS | Task | Type | Duration | Start | Finish | Predecessors | Total slack | Free slack | Resources | Work |
| --- | --- | --- | --- | --- | --- | --- | --- | --- | --- | --- | --- |
| 29 | 8 | **Fase6: Benestare** |  | 36d | 2004-05-27 | 2004-07-15 |  | 2d |  |  | 488h |
| 30 | 8.1 | Verifica dimensionale, funzionale e di montaggio |  | 1w | 2004-05-27 | 2004-06-02 | 27 | 2d | 0d | Fornitore | 40h |
| 31 | 8.2 | Messa a punto |  | 4w | 2004-06-03 | 2004-06-30 | 30 | 2d | 0d | Fornitore | 160h |
| 32 | 8.3 | Trattamenti |  | 4w | 2004-06-03 | 2004-06-30 | 30 | 2d | 0d | Fornitore | 160h |
| 33 | 8.4 | Nuovo collaudo |  | 1w | 2004-07-01 | 2004-07-07 | 31, 32 | 2d | 0d | Fornitore | 40h |
| 34 | 8.5 | Verifica dimensionale e funzionale |  | 1w | 2004-07-08 | 2004-07-14 | 33 | 2d | 0d | Merloni | 40h |
| 35 | 8.6 | Benestare dimensionale e funzionale |  | 1d | 2004-07-15 | 2004-07-15 | 34 | 2d |  | Merloni | 8h |
| 36 | 8.7 | Completamento stampo |  | 1w | 2004-07-08 | 2004-07-14 | 33 | 3d |  | Fornitore | 40h |
| 38 | 9 | Cruscotto |  | 1d? | 2004-01-01 | 2004-01-01 |  | 142d |  |  |  |
| 39 | 10 | **Fase1: Apertura contatti con I Fornitori** |  | 5d | 2004-01-01 | 2004-01-07 |  | 27d |  |  | 40h |
| 40 | 10.1 | Presentazione disegno e richiesta offerte | milestone | 0d | 2004-01-01 | 2004-01-01 |  | 27d | 0d | Merloni |  |
| 41 | 10.2 | Presentazione offerte |  | 1w | 2004-01-01 | 2004-01-07 | 40 | 27d | 0d | Fornitori | 40h |
| 42 | 10.3 | Checkpoint1 | milestone | 0d | 2004-01-07 | 2004-01-07 | 41 | 27d | 0d | Team |  |
| 43 | 11 | **Fase2: Definizioni dettagli e selezione Fornitore** |  | 10d | 2004-01-08 | 2004-01-21 |  | 27d |  |  | 120h |
| 44 | 11.1 | Definizione piano di lavoro |  | 1w | 2004-01-08 | 2004-01-14 | 42 | 133d |  | Merloni | 40h |
| 45 | 11.2 | Analisi offerte |  | 2w | 2004-01-08 | 2004-01-21 | 41, 42 | 27d | 0d | Merloni | 80h |
| 46 | 11.3 | Accettazione offerta | milestone | 0d | 2004-01-21 | 2004-01-21 | 45 | 27d | 0d | Merloni |  |
| 47 | 11.4 | Checkpoint2 | milestone | 0d | 2004-01-21 | 2004-01-21 | 42, 46 | 27d | 0d | Team |  |
| 48 | 12 | **Fase3: Codesign** |  | 25d | 2004-01-22 | 2004-02-25 |  | 27d |  |  | 320h |
| 49 | 12.1 | Consegna Pelle 3D e versionamenti |  | 1w | 2004-01-22 | 2004-01-28 | 46, 47 | 27d | 0d | Merloni | 40h |
| 50 | 12.2 | Codesign |  | 3w | 2004-01-29 | 2004-02-18 | 49 | 27d | 0d | Fornitore; Merloni | 240h |
| 51 | 12.3 | Release al Codesign |  | 1w | 2004-02-19 | 2004-02-25 | 50 | 27d | 0d | Merloni | 40h |
| 52 | 12.4 | Checkpoint 3 | milestone | 0d | 2004-02-25 | 2004-02-25 | 51 | 27d | 0d | Team |  |
| 53 | 13 | Approvigionamenti materiali |  | 3w | 2004-01-22 | 2004-02-11 | 46, 47 | 113d |  | Fornitore | 120h |

| ID | WBS | Task | Type | Duration | Start | Finish | Predecessors | Total slack | Free slack | Resources | Work |
| --- | --- | --- | --- | --- | --- | --- | --- | --- | --- | --- | --- |
| 54 | 14 | **Fase4: Progettazione** |  | 20d | 2004-02-26 | 2004-03-24 |  | 27d |  |  | 200h |
| 55 | 14.1 | Progettazione di massima |  | 1w | 2004-02-26 | 2004-03-03 | 52 | 27d | 0d | Fornitore | 40h |
| 56 | 14.2 | Progettazione dettagli |  | 2w | 2004-02-26 | 2004-03-10 | 52 | 83d | 0d | Fornitore | 80h |
| 57 | 14.3 | Valutazione dell'opportunità di Analisi Sperimentali anche a mezzo di prototipi |  | 1w | 2004-03-11 | 2004-03-17 | 56 | 83d | 0d | Merloni | 40h |
| 58 | 14.4 | Realizzazioni analisi e prototipi |  | 1w | 2004-03-18 | 2004-03-24 | 57 | 83d |  | Fornitore | 40h |
| 59 | 14.5 | checkpoint5 | milestone | 0d | 2004-03-17 | 2004-03-17 | 56, 57 | 88d |  | Team |  |
| 60 | 15 | **Fase5: Costruzione** |  | 50d | 2004-03-04 | 2004-05-12 |  | 27d |  |  | 520h |
| 61 | 15.1 | Lavorazione portastampi |  | 3w | 2004-03-04 | 2004-03-24 | 55 | 47d | 20d | Fornitore | 120h |
| 62 | 15.2 | Lavorazione parti stampanti |  | 7w | 2004-03-04 | 2004-04-21 | 55 | 27d | 0d | Fornitore | 280h |
| 63 | 15.3 | Assemblaggio Stampi |  | 2w | 2004-04-22 | 2004-05-05 | 61, 62 | 27d | 0d | Fornitore | 80h |
| 64 | 15.4 | Prima campionatura |  | 1w | 2004-05-06 | 2004-05-12 | 63 | 27d | 0d | Fornitore | 40h |
| 65 | 15.5 | Checkpoint6 | milestone | 0d | 2004-05-12 | 2004-05-12 | 64 | 48d |  | Team |  |
| 66 | 16 | **Fase6: Benestare** |  | 21d | 2004-05-13 | 2004-06-10 |  | 27d |  |  | 328h |
| 67 | 16.1 | Verifica dimensionale, funzionale e di montaggio |  | 0.5w | 2004-05-13 | 2004-05-17 | 64 | 27d | 0d | Fornitore; Merloni | 40h |
| 68 | 16.2 | Messa a punto |  | 2w | 2004-05-17 | 2004-05-31 | 67 | 27d | 0d | Fornitore | 80h |
| 69 | 16.3 | Trattamenti |  | 2w | 2004-05-17 | 2004-05-31 | 67 | 27d | 0d | Fornitore | 80h |
| 70 | 16.4 | Nuovo collaudo |  | 0.5w | 2004-05-31 | 2004-06-02 | 68, 69 | 27d | 0d | Fornitore; Merloni | 40h |
| 71 | 16.5 | Verifica dimensionale e funzionale |  | 1w | 2004-06-03 | 2004-06-09 | 70 | 27d | 0d | Merloni | 40h |
| 72 | 16.6 | Benestare dimensionale e funzionale |  | 1d | 2004-06-10 | 2004-06-10 | 71 | 27d |  | Merloni | 8h |
| 73 | 16.7 | Completamento stampo |  | 1w | 2004-06-03 | 2004-06-09 | 70 | 28d |  | Fornitore | 40h |
| 75 | 17 | Oblò |  | 1d? | 2004-01-01 | 2004-01-01 |  | 142d |  |  |  |
| 76 | 18 | **Fase1: Apertura contatti con I Fornitori** |  | 5d | 2004-01-01 | 2004-01-07 |  | 0d |  |  | 40h |
| 77 | 18.1 | Presentazione disegno e richiesta offerte | milestone | 0d | 2004-01-01 | 2004-01-01 |  | 0d |  | Merloni |  |
| 78 | 18.2 | Presentazione offerte |  | 1w | 2004-01-01 | 2004-01-07 | 77 | 0d |  | Fornitori | 40h |
| 79 | 18.3 | Checkpoint1 | milestone | 0d | 2004-01-07 | 2004-01-07 | 78 | 0d |  | Team |  |

| ID | WBS | Task | Type | Duration | Start | Finish | Predecessors | Total slack | Free slack | Resources | Work |
| --- | --- | --- | --- | --- | --- | --- | --- | --- | --- | --- | --- |
| 80 | 19 | **Fase2: Definizioni dettagli e selezione Fornitore** |  | 10d | 2004-01-08 | 2004-01-21 |  | 0d |  |  | 120h |
| 81 | 19.1 | Definizione piano di lavoro |  | 1w | 2004-01-08 | 2004-01-14 | 79 | 133d |  | Merloni | 40h |
| 82 | 19.2 | Analisi offerte |  | 2w | 2004-01-08 | 2004-01-21 | 78, 79 | 0d |  | Merloni | 80h |
| 83 | 19.3 | Accettazione offerta | milestone | 0d | 2004-01-21 | 2004-01-21 | 82 | 0d |  | Merloni |  |
| 84 | 19.4 | Checkpoint2 | milestone | 0d | 2004-01-21 | 2004-01-21 | 79, 83 | 0d |  | Team |  |
| 85 | 20 | **Fase3: Codesign** |  | 25d | 2004-01-22 | 2004-02-25 |  | 0d |  |  | 320h |
| 86 | 20.1 | Consegna Pelle 3D |  | 1w | 2004-01-22 | 2004-01-28 | 83, 84 | 0d |  | Merloni | 40h |
| 87 | 20.2 | Codesign |  | 3w | 2004-01-29 | 2004-02-18 | 86 | 0d |  | Fornitore; Merloni | 240h |
| 88 | 20.3 | Release al Codesign |  | 1w | 2004-02-19 | 2004-02-25 | 87 | 0d |  | Merloni | 40h |
| 89 | 20.4 | Checkpoint 3 | milestone | 0d | 2004-02-25 | 2004-02-25 | 88 | 0d |  | Team |  |
| 90 | 21 | Approvigionamenti materiali |  | 3w | 2004-01-22 | 2004-02-11 | 83, 84 | 113d |  | Fornitore | 120h |
| 91 | 22 | **Fase4: Progettazione** |  | 30d | 2004-02-26 | 2004-04-07 |  | 0d |  |  | 320h |
| 92 | 22.1 | Progettazione di massima |  | 2w | 2004-02-26 | 2004-03-10 | 89 | 30d | 0d | Fornitore | 80h |
| 93 | 22.2 | Progettazione dettagli |  | 4w | 2004-02-26 | 2004-03-24 | 89 | 0d |  | Fornitore | 160h |
| 94 | 22.3 | Valutazione dell'opportunità di Analisi Sperimentali anche a mezzo di prototipi |  | 1w | 2004-03-25 | 2004-03-31 | 93 | 73d | 0d | Merloni | 40h |
| 95 | 22.4 | Realizzazioni analisi e prototipi |  | 1w | 2004-04-01 | 2004-04-07 | 94 | 73d |  | Fornitore | 40h |
| 96 | 22.5 | checkpoint5 | milestone | 0d | 2004-03-31 | 2004-03-31 | 93, 94 | 78d |  | Team |  |
| 97 | 23 | **Fase5: Costruzione** |  | 61d | 2004-03-11 | 2004-06-03 |  | 10d |  |  | 568h |
| 98 | 23.1 | Lavorazione portastampi |  | 4w | 2004-03-11 | 2004-04-07 | 92 | 30d |  | Fornitore | 160h |
| 99 | 23.2 | Lavorazione parti stampanti |  | 8w | 2004-03-25 | 2004-05-19 | 93 | 0d |  | Fornitore | 320h |
| 100 | 23.3 | Assemblaggio Stampi |  | 2w | 2004-05-20 | 2004-06-02 | 98, 99 | 0d |  | Fornitore | 80h |
| 101 | 23.4 | Prima campionatura |  | 1d | 2004-06-03 | 2004-06-03 | 100 | 0d |  | Fornitore | 8h |
| 102 | 23.5 | Checkpoint6 | milestone | 0d | 2004-06-03 | 2004-06-03 | 101 | 32d |  | Team |  |
| 103 | 24 | **Fase6: Benestare** |  | 32d | 2004-06-04 | 2004-07-19 |  | 0d |  |  | 456h |
| 104 | 24.1 | Verifica dimensionale, funzionale e di montaggio |  | 1w | 2004-06-04 | 2004-06-10 | 101 | 0d |  | Fornitore | 40h |
| 105 | 24.2 | Messa a punto |  | 4w | 2004-06-11 | 2004-07-08 | 104 | 0d |  | Fornitore | 160h |
| 106 | 24.3 | Trattamenti |  | 4w | 2004-06-11 | 2004-07-08 | 104 | 0d |  | Fornitore | 160h |
| 107 | 24.4 | Nuovo collaudo |  | 1d | 2004-07-09 | 2004-07-09 | 105, 106 | 0d |  | Fornitore | 8h |
| 108 | 24.5 | Verifica dimensionale e funzionale |  | 1w | 2004-07-12 | 2004-07-16 | 107 | 0d |  | Merloni | 40h |
| 109 | 24.6 | Benestare dimensionale e funzionale |  | 1d | 2004-07-19 | 2004-07-19 | 108 | 0d |  | Merloni | 8h |
| 110 | 24.7 | Completamento stampo |  | 1w | 2004-07-12 | 2004-07-16 | 107 | 1d |  | Fornitore | 40h |
| 112 | 25 | Zoccolo |  | 1d? | 2004-01-01 | 2004-01-01 |  | 142d |  |  |  |

| ID | WBS | Task | Type | Duration | Start | Finish | Predecessors | Total slack | Free slack | Resources | Work |
| --- | --- | --- | --- | --- | --- | --- | --- | --- | --- | --- | --- |
| 113 | 26 | **Fase1: Apertura contatti con I Fornitori** |  | 5d | 2004-01-01 | 2004-01-07 |  | 25d |  |  | 40h |
| 114 | 26.1 | Presentazione disegno e richiesta offerte | milestone | 0d | 2004-01-01 | 2004-01-01 |  | 25d | 0d | Merloni |  |
| 115 | 26.2 | Presentazione offerte |  | 1w | 2004-01-01 | 2004-01-07 | 114 | 25d | 0d | Fornitori | 40h |
| 116 | 26.3 | Checkpoint1 | milestone | 0d | 2004-01-07 | 2004-01-07 | 115 | 25d | 0d | Team |  |
| 117 | 27 | **Fase2: Definizioni dettagli e selezione Fornitore** |  | 10d | 2004-01-08 | 2004-01-21 |  | 25d |  |  | 120h |
| 118 | 27.1 | Definizione piano di lavoro |  | 1w | 2004-01-08 | 2004-01-14 | 116 | 133d |  | Merloni | 40h |
| 119 | 27.2 | Analisi offerte |  | 2w | 2004-01-08 | 2004-01-21 | 115, 116 | 25d | 0d | Merloni | 80h |
| 120 | 27.3 | Accettazione offerta | milestone | 0d | 2004-01-21 | 2004-01-21 | 119 | 25d | 0d | Merloni |  |
| 121 | 27.4 | Checkpoint2 | milestone | 0d | 2004-01-21 | 2004-01-21 | 116, 120 | 25d | 0d | Team |  |
| 122 | 28 | **Fase3: Codesign** |  | 20d | 2004-01-22 | 2004-02-18 |  | 25d |  |  | 240h |
| 123 | 28.1 | Consegna Pelle 3D |  | 1w | 2004-01-22 | 2004-01-28 | 120, 121 | 25d | 0d | Merloni | 40h |
| 124 | 28.2 | Codesign |  | 2w | 2004-01-29 | 2004-02-11 | 123 | 25d | 0d | Fornitore; Merloni | 160h |
| 125 | 28.3 | Release al Codesign |  | 1w | 2004-02-12 | 2004-02-18 | 124 | 25d | 0d | Merloni | 40h |
| 126 | 28.4 | Checkpoint 3 | milestone | 0d | 2004-02-18 | 2004-02-18 | 125 | 25d | 0d | Team |  |
| 127 | 29 | Approvigionamenti materiali |  | 3w | 2004-01-22 | 2004-02-11 | 120, 121 | 113d |  | Fornitore | 120h |
| 128 | 30 | **Fase4: Progettazione** |  | 25d | 2004-02-19 | 2004-03-24 |  | 25d |  |  | 240h |
| 129 | 30.1 | Progettazione di massima |  | 1w | 2004-02-19 | 2004-02-25 | 126 | 50d | 0d | Fornitore | 40h |
| 130 | 30.2 | Progettazione dettagli |  | 3w | 2004-02-19 | 2004-03-10 | 126 | 25d | 0d | Fornitore | 120h |
| 131 | 30.3 | Valutazione dell'opportunità di Analisi Sperimentali anche a mezzo di prototipi |  | 1w | 2004-03-11 | 2004-03-17 | 130 | 83d | 0d | Merloni | 40h |
| 132 | 30.4 | Realizzazioni analisi e prototipi |  | 1w | 2004-03-18 | 2004-03-24 | 131 | 83d |  | Fornitore | 40h |
| 133 | 30.5 | checkpoint5 | milestone | 0d | 2004-03-17 | 2004-03-17 | 130, 131 | 88d |  | Team |  |
| 134 | 31 | **Fase5: Costruzione** |  | 51d | 2004-02-26 | 2004-05-06 |  | 35d |  |  | 448h |
| 135 | 31.1 | Lavorazione portastampi |  | 3w | 2004-02-26 | 2004-03-17 | 129 | 50d | 25d | Fornitore | 120h |
| 136 | 31.2 | Lavorazione parti stampanti |  | 6w | 2004-03-11 | 2004-04-21 | 130 | 25d | 0d | Fornitore | 240h |
| 137 | 31.3 | Assemblaggio Stampi |  | 2w | 2004-04-22 | 2004-05-05 | 135, 136 | 25d | 0d | Fornitore | 80h |
| 138 | 31.4 | Prima campionatura |  | 1d | 2004-05-06 | 2004-05-06 | 137 | 25d | 0d | Fornitore | 8h |
| 139 | 31.5 | Checkpoint6 | milestone | 0d | 2004-05-06 | 2004-05-06 | 138 | 52d |  | Team |  |

| ID | WBS | Task | Duration | Start | Finish | Predecessors | Total slack | Free slack | Resources | Work |
| --- | --- | --- | --- | --- | --- | --- | --- | --- | --- | --- |
| 140 | 32 | **Fase6: Benestare** | 27d | 2004-05-07 | 2004-06-14 |  | 25d |  |  | 376h |
| 141 | 32.1 | Verifica dimensionale, funzionale e di montaggio | 1w | 2004-05-07 | 2004-05-13 | 138 | 25d | 0d | Fornitore | 40h |
| 142 | 32.2 | Messa a punto | 3w | 2004-05-14 | 2004-06-03 | 141 | 25d | 0d | Fornitore | 120h |
| 143 | 32.3 | Trattamenti | 3w | 2004-05-14 | 2004-06-03 | 141 | 25d | 0d | Fornitore | 120h |
| 144 | 32.4 | Nuovo collaudo | 1d | 2004-06-04 | 2004-06-04 | 142, 143 | 25d | 0d | Fornitore | 8h |
| 145 | 32.5 | Verifica dimensionale e funzionale | 1w | 2004-06-07 | 2004-06-11 | 144 | 25d | 0d | Merloni | 40h |
| 146 | 32.6 | Benestare dimensionale e funzionale | 1d | 2004-06-14 | 2004-06-14 | 145 | 25d |  | Merloni | 8h |
| 147 | 32.7 | Completamento stampo | 1w | 2004-06-07 | 2004-06-11 | 144 | 26d |  | Fornitore | 40h |
