# VascaPlastica

Schedule from MS Project, 2004-01-01 to 2004-11-01.
Merloni Elettrodomestici

## Calendars

- Standard: Mon-Fri 08:00-12:00, 13:00-17:00; Sat-Sun off.

## Resources

| Resource |
| --- |
| Fornitore |
| Merloni |
| Team |

## Schedule

| ID | WBS | Task | Type | Duration | Start | Finish | Predecessors | Total slack | Free slack | Resources | Work |
| --- | --- | --- | --- | --- | --- | --- | --- | --- | --- | --- | --- |
| 1 | 1 | **Fase1: Apertura contatti con I fornitori** |  | 10d | 2004-01-01 | 2004-01-14 |  | 0d |  |  | 160h |
| 2 | 1.1 | Informazioni preliminari su target-specifiche |  | 2w | 2004-01-01 | 2004-01-14 |  | 0d |  | Merloni | 80h |
| 3 | 1.2 | Impostazione lay-out fattibiltà ingombri sul target-specifiche |  | 2w | 2004-01-01 | 2004-01-14 |  | 0d |  | Fornitore | 80h |
| 4 | 1.3 | Checkpoint1 | milestone | 0d | 2004-01-14 | 2004-01-14 | 3 | 0d |  | Team |  |
| 5 | 2 | **Fase2: Definizione specifiche e selezione fornitori** |  | 10d | 2004-01-15 | 2004-01-28 |  | 0d |  |  | 160h |
| 6 | 2.1 | Definizione piano di Start-up |  | 1w | 2004-01-15 | 2004-01-21 | 4 | 203d |  | Merloni | 40h |
| 7 | 2.2 | Analisi lay-out MG |  | 1w | 2004-01-15 | 2004-01-21 | 3, 4 | 5d | 0d | Merloni | 40h |
| 8 | 2.3 | Definizione completa delle specifiche della vasca nei suoi dettagli |  | 1w | 2004-01-15 | 2004-01-21 | 2, 4 | 0d |  | Merloni | 40h |
| 9 | 2.4 | Analisi di fattibilità e definizione delle soluzioni |  | 1w | 2004-01-22 | 2004-01-28 | 8 | 0d |  | Fornitore | 40h |
| 10 | 2.5 | Accettazione offerta lay-out vasca/flangia | milestone | 0d | 2004-01-21 | 2004-01-21 | 7 | 5d |  | Merloni |  |
| 11 | 2.6 | Checkpoint2 | milestone | 0d | 2004-01-28 | 2004-01-28 | 9, 10, 4 | 0d |  | Team |  |
| 12 | 3 | **Fase3: Sviluppo** |  | 25d | 2004-01-29 | 2004-03-03 |  | 0d |  |  | 200h |
| 13 | 3.1 | Richieste sviluppo |  | 2w | 2004-01-29 | 2004-02-11 | 11, 8, 9 | 0d |  | Merloni | 80h |
| 14 | 3.2 | Presentazione e analisi soluzioni |  | 3w | 2004-02-12 | 2004-03-03 | 13 | 0d |  | Fornitore | 120h |
| 15 | 3.3 | Checkpoint 3 | milestone | 0d | 2004-03-03 | 2004-03-03 | 13, 14 | 0d |  | Team |  |
| 16 | 4 | **Fase4: Dimensionamenti** |  | 10d | 2004-03-04 | 2004-03-17 |  | 123d |  |  | 80h |
| 17 | 4.1 | Definizione soluzioni definitive e dimensionamenti |  | 2w | 2004-03-04 | 2004-03-17 | 9, 14, 15 | 123d | 0d | Fornitore | 80h |
| 18 | 4.2 | Checkpoint 4 | milestone | 0d | 2004-03-17 | 2004-03-17 | 17 | 123d | 0d | Team |  |
| 19 | 5 | **Fase5: Analisi** |  | 50d | 2004-03-04 | 2004-05-12 |  | 0d |  |  | 520h |
| 20 | 5.1 | Costruzione Modello 3D |  | 3w | 2004-03-04 | 2004-03-24 | 9, 14, 15 | 0d |  | Fornitore | 120h |
| 21 | 5.2 | Analisi Mold Flow |  | 1w | 2004-03-25 | 2004-03-31 | 20 | 0d |  | Fornitore | 40h |
| 22 | 5.3 | Analisi strutturale |  | 1w | 2004-04-01 | 2004-04-07 | 21 | 0d |  | Fornitore | 40h |
| 23 | 5.4 | Valutazione dell'opportunità di Analisi Sperimentali anche a mezzo di prototipi |  | 1w | 2004-03-18 | 2004-03-24 | 17, 18 | 123d | 0d | Merloni | 40h |
| 24 | 5.5 | Realizzazioni analisi e prototipi |  | 7w | 2004-03-25 | 2004-05-12 | 23 | 123d |  | Fornitore | 280h |
| 25 | 5.6 | checkpoint5 | milestone | 0d | 2004-04-07 | 2004-04-07 | 22, 23 | 148d |  | Team |  |

| ID | WBS | Task | Type | Duration | Start | Finish | Predecessors | Total slack | Resources | Work |
| --- | --- | --- | --- | --- | --- | --- | --- | --- | --- | --- |
| 26 | 6 | **Fase6: Progettazione e Costruzione** |  | 121d | 2004-04-01 | 2004-09-16 |  | 5d |  | 1288h |
| 27 | 6.1 | Definizione lay-out Stampi |  | 3w | 2004-04-01 | 2004-04-21 | 21 | 138d | Fornitore | 120h |
| 28 | 6.2 | Progettazione Stampi |  | 6w | 2004-04-08 | 2004-05-19 | 22 | 118d | Fornitore | 240h |
| 29 | 6.3 | Costruzione stampi |  | 23w | 2004-04-08 | 2004-09-15 | 22 | 0d | Fornitore | 920h |
| 30 | 6.4 | Prima campionatura |  | 1d | 2004-09-16 | 2004-09-16 | 29 | 0d | Fornitore | 8h |
| 31 | 6.5 | Checkpoint6 | milestone | 0d | 2004-09-16 | 2004-09-16 | 30 | 0d | Team |  |
| 32 | 7 | **Fase7: Benestare** |  | 32d | 2004-09-17 | 2004-11-01 | 31 | 0d |  | 336h |
| 33 | 7.1 | Verifica dimensionale e funzionale |  | 1w | 2004-09-17 | 2004-09-23 | 31, 30 | 0d | Merloni; Fornitore | 80h |
| 34 | 7.2 | Prima messa a punto degli stampi |  | 5d | 2004-09-24 | 2004-09-30 | 33 | 0d | Fornitore; Merloni | 80h |
| 35 | 7.3 | Nuovo collaudo |  | 1d | 2004-10-01 | 2004-10-01 | 34 | 0d | Fornitore | 8h |
| 36 | 7.4 | Rilievo non conformità |  | 1w | 2004-10-04 | 2004-10-08 | 35 | 0d | Merloni | 40h |
| 37 | 7.5 | Trattamenti |  | 1w | 2004-10-11 | 2004-10-15 | 36 | 0d | Fornitore | 40h |
| 38 | 7.6 | Nuovo collaudo |  | 1d | 2004-10-18 | 2004-10-18 | 37 | 0d | Fornitore | 8h |
| 39 | 7.7 | Verifica dimensionale e funzionale |  | 1w | 2004-10-19 | 2004-10-25 | 38 | 0d | Merloni | 40h |
| 40 | 7.8 | Benestare dimensionale e funzionale | milestone | 0d | 2004-10-25 | 2004-10-25 | 39 | 0d | Merloni |  |
| 41 | 7.9 | Completamento stampo |  | 1w | 2004-10-26 | 2004-11-01 | 40 | 0d | Fornitore | 40h |

Notes:
- 37: I trattamenti dura 1 settimana per ogni versione, quindi 2 versioni 2 settimane.
