# Alluminio

Schedule from MS Project, 2004-01-01 to 2004-07-09.
Merloni Elettrodomestici

## Calendars

- Standard: Mon-Fri 08:00-12:00, 13:00-17:00; Sat-Sun off.

## Resources

| Resource |
| --- |
| Fornitore |
| Merloni |
| Team |
| Fornitori |

## Schedule

| ID | WBS | Task | Type | Duration | Start | Finish | Predecessors | Total slack | Free slack | Resources | Work |
| --- | --- | --- | --- | --- | --- | --- | --- | --- | --- | --- | --- |
| 1 | 1 | Crociera Alluminio 2 Figure |  | 1d? | 2004-01-01 | 2004-01-01 |  | 136d |  |  |  |
| 2 | 2 | Selezione Fornitori |  | 1w | 2004-01-01 | 2004-01-07 |  | 0d |  |  |  |
| 3 | 3 | **Fase1: Apertura contatti con I fornitori** |  | 7d | 2004-01-08 | 2004-01-16 | 2 | 0d |  |  | 56h |
| 4 | 3.1 | Presentazione disegno e richiesta di ipotesi di caratteristiche tecniche, lay-out e costo stampo |  | 1d | 2004-01-08 | 2004-01-08 | 2 | 0d |  | Merloni | 8h |
| 5 | 3.2 | Presentazione offerte con scheda stampo |  | 1.2w | 2004-01-09 | 2004-01-16 | 4 | 0d |  | Fornitori | 48h |
| 6 | 3.3 | Checkpoint1 | milestone | 0d | 2004-01-16 | 2004-01-16 | 5 | 0d |  | Team |  |
| 7 | 4 | **Fase2:Definizione dettaglie e selezione fornitori** |  | 42d | 2004-01-19 | 2004-03-16 |  | 0d |  |  | 376h |
| 8 | 4.1 | Analisi e selezione tra I lay-out proposti |  | 8.2w | 2004-01-19 | 2004-03-15 | 5, 6 | 0d |  | Merloni | 328h |
| 9 | 4.2 | Accettazione offerta |  | 1d | 2004-03-16 | 2004-03-16 | 8 | 0d |  | Merloni | 8h |
| 10 | 4.3 | Definizione completa delle specifiche del componente nei suoi dettagli |  | 1w | 2004-01-19 | 2004-01-23 | 4, 6 | 120d |  | Merloni | 40h |
| 11 | 4.4 | Checkpoint2 | milestone | 0d | 2004-03-16 | 2004-03-16 | 9 | 0d |  | Team |  |
| 12 | 5 | **Fase4: Progettazione** |  | 30d | 2004-03-17 | 2004-04-27 |  | 0d |  |  | 320h |
| 13 | 5.1 | Definizione soluzioni definitive e dimensionamenti |  | 2w | 2004-03-17 | 2004-03-30 | 11 | 0d |  | Fornitore | 80h |
| 14 | 5.2 | Approvigionamenti materiali |  | 2w | 2004-03-31 | 2004-04-13 | 13 | 10d |  | Merloni | 80h |
| 15 | 5.3 | Progettazione Stampi |  | 4w | 2004-03-31 | 2004-04-27 | 13 | 0d |  | Fornitore | 160h |
| 16 | 5.4 | Checkpoint 4 | milestone | 0d | 2004-04-27 | 2004-04-27 | 15, 14 | 53d |  | Team |  |
| 17 | 6 | **Fase5:Testing** |  | 15d | 2004-04-28 | 2004-05-18 |  | 38d |  |  | 200h |
| 18 | 6.1 | Valutazione dell'opportunità di Analisi Sperimentali anche a mezzo di prototipi |  | 1w | 2004-04-28 | 2004-05-04 | 15 | 38d | 0d | Merloni | 40h |
| 19 | 6.2 | Realizzazioni prototipi e analisi |  | 10d | 2004-05-05 | 2004-05-18 | 18 | 38d |  | Fornitore; Merloni | 160h |
| 20 | 6.3 | checkpoint5 | milestone | 0d | 2004-05-04 | 2004-05-04 | 18 | 48d |  | Team |  |
| 21 | 7 | **Fase6:Costruzione** |  | 36d | 2004-04-28 | 2004-06-16 |  | 0d |  |  | 288h |
| 22 | 7.1 | Costruzione stampi |  | 7w | 2004-04-28 | 2004-06-15 | 14, 15 | 0d |  | Fornitore | 280h |
| 23 | 7.2 | Prima campionatura |  | 1d | 2004-06-16 | 2004-06-16 | 22 | 0d |  | Fornitore | 8h |
| 24 | 7.3 | Checkpoint6 | milestone | 0d | 2004-06-16 | 2004-06-16 | 23 | 17d |  | Team |  |

| ID | WBS | Task | Type | Duration | Start | Finish | Predecessors | Total slack | Free slack | Resources | Work |
| --- | --- | --- | --- | --- | --- | --- | --- | --- | --- | --- | --- |
| 25 | 8 | **Fase7: Benestare** |  | 17d | 2004-06-17 | 2004-07-09 |  | 0d |  |  | 216h |
| 26 | 8.1 | Verifica dimensionale e funzionale |  | 1w | 2004-06-17 | 2004-06-23 | 23 | 0d |  | Merloni; Fornitore | 80h |
| 27 | 8.2 | Prima messa a punto degli stampi |  | 1w | 2004-06-24 | 2004-06-30 | 26 | 0d |  | Fornitore; Merloni | 80h |
| 28 | 8.3 | Nuovo collaudo |  | 1d | 2004-07-01 | 2004-07-01 | 27 | 0d |  | Fornitore | 8h |
| 29 | 8.4 | Rilievo non conformità |  | 1w | 2004-07-02 | 2004-07-08 | 28 | 0d |  | Merloni | 40h |
| 30 | 8.5 | Benestare dimensionale e funzionale |  | 1d | 2004-07-09 | 2004-07-09 | 29 | 0d |  | Merloni | 8h |
| 31 | 8.6 | Checkpoint7 | milestone | 0d | 2004-07-09 | 2004-07-09 | 30 | 0d |  |  |  |
| 33 | 9 | Puleggia Alluminio 1 Figura |  | 1d? | 2004-01-01 | 2004-01-01 |  | 0d |  |  |  |
| 34 | 10 | Selezione Fornitori |  | 1w | 2004-01-01 | 2004-01-07 |  | 37d | 0d |  |  |
| 35 | 11 | **Fase1: Apertura contatti con I fornitori** |  | 6d | 2004-01-08 | 2004-01-15 | 34 | 37d |  |  | 48h |
| 36 | 11.1 | Presentazione disegno e richiesta di ipotesi di caratteristiche tecniche, lay-out e costo stampo |  | 1d | 2004-01-08 | 2004-01-08 | 34 | 37d | 0d | Merloni | 8h |
| 37 | 11.2 | Presentazione offerte con scheda stampo |  | 1w | 2004-01-09 | 2004-01-15 | 36 | 37d | 0d | Fornitori | 40h |
| 38 | 11.3 | Checkpoint1 | milestone | 0d | 2004-01-15 | 2004-01-15 | 37 | 37d | 0d | Team |  |
| 39 | 12 | **Fase2:Definizione dettaglie e selezione fornitori** |  | 6d | 2004-01-16 | 2004-01-23 |  | 37d |  |  | 88h |
| 40 | 12.1 | Analisi e selezione tra I lay-out proposti |  | 1w | 2004-01-16 | 2004-01-22 | 37, 38 | 37d | 0d | Merloni | 40h |
| 41 | 12.2 | Accettazione offerta |  | 1d | 2004-01-23 | 2004-01-23 | 40 | 37d | 0d | Merloni | 8h |
| 42 | 12.3 | Definizione completa delle specifiche del componente nei suoi dettagli |  | 1w | 2004-01-16 | 2004-01-22 | 36, 38 | 64d |  | Merloni | 40h |
| 43 | 12.4 | Checkpoint2 | milestone | 0d | 2004-01-23 | 2004-01-23 | 38, 41 | 37d | 0d | Team |  |
| 44 | 13 | **Fase4: Progettazione** |  | 30d | 2004-01-26 | 2004-03-05 |  | 37d |  |  | 320h |
| 45 | 13.1 | Definizione soluzioni definitive e dimensionamenti |  | 2w | 2004-01-26 | 2004-02-06 | 43 | 37d | 0d | Fornitore | 80h |
| 46 | 13.2 | Approvigionamenti materiali |  | 2w | 2004-02-09 | 2004-02-20 | 45 | 5d |  | Merloni | 80h |
| 47 | 13.3 | Progettazione Stampi |  | 4w | 2004-02-09 | 2004-03-05 | 45 | 37d | 0d | Fornitore | 160h |
| 48 | 13.4 | Checkpoint 4 | milestone | 0d | 2004-03-05 | 2004-03-05 | 46, 47 | 53d |  | Team |  |
| 49 | 14 | **Fase5:Testing** |  | 15d | 2004-03-08 | 2004-03-26 |  | 75d |  |  | 200h |
| 50 | 14.1 | Valutazione dell'opportunità di Analisi Sperimentali anche a mezzo di prototipi |  | 1w | 2004-03-08 | 2004-03-12 | 47 | 38d | 0d | Merloni | 40h |
| 51 | 14.2 | Realizzazioni prototip e analisi |  | 10d | 2004-03-15 | 2004-03-26 | 50 | 38d |  | Fornitore; Merloni | 160h |
| 52 | 14.3 | checkpoint5 | milestone | 0d | 2004-03-12 | 2004-03-12 | 50 | 48d |  | Team |  |

| ID | WBS | Task | Type | Duration | Start | Finish | Predecessors | Total slack | Free slack | Resources | Work |
| --- | --- | --- | --- | --- | --- | --- | --- | --- | --- | --- | --- |
| 53 | 15 | **Fase6:Costruzione** |  | 36d | 2004-03-08 | 2004-04-26 |  | 37d |  |  | 288h |
| 54 | 15.1 | Costruzione stampi |  | 7w | 2004-03-08 | 2004-04-23 | 46, 47 | 37d | 0d | Fornitore | 280h |
| 55 | 15.2 | Prima campionatura |  | 1d | 2004-04-26 | 2004-04-26 | 54 | 37d | 0d | Fornitore | 8h |
| 56 | 15.3 | Checkpoint6 | milestone | 0d | 2004-04-26 | 2004-04-26 | 55 | 17d |  | Team |  |
| 57 | 16 | **Fase7: Benestare** |  | 17d | 2004-04-27 | 2004-05-19 |  | 37d |  |  | 216h |
| 58 | 16.1 | Verifica dimensionale e funzionale |  | 1w | 2004-04-27 | 2004-05-03 | 55 | 37d | 0d | Merloni; Fornitore | 80h |
| 59 | 16.2 | Prima messa a punto degli stampi |  | 1w | 2004-05-04 | 2004-05-10 | 58 | 37d | 0d | Fornitore; Merloni | 80h |
| 60 | 16.3 | Nuovo collaudo |  | 1d | 2004-05-11 | 2004-05-11 | 59 | 37d | 0d | Fornitore | 8h |
| 61 | 16.4 | Rilievo non conformità |  | 1w | 2004-05-12 | 2004-05-18 | 60 | 37d | 0d | Merloni | 40h |
| 62 | 16.5 | Benestare dimensionale e funzionale |  | 1d | 2004-05-19 | 2004-05-19 | 61 | 37d | 0d | Merloni | 8h |
| 63 | 16.6 | Checkpoint7 | milestone | 0d | 2004-05-19 | 2004-05-19 | 62 | 37d |  |  |  |
| 65 | 17 | Mozzo Alluminio 4 Figure |  | 1d? | 2004-01-01 | 2004-01-01 |  | 0d |  |  |  |
| 66 | 18 | Selezione Fornitori |  | 1w | 2004-01-01 | 2004-01-07 |  | 57d | 0d |  |  |
| 67 | 19 | **Fase1: Apertura contatti con I fornitori** |  | 6d | 2004-01-08 | 2004-01-15 | 66 | 57d |  |  | 48h |
| 68 | 19.1 | Presentazione disegno e richiesta di ipotesi di caratteristiche tecniche, lay-out e costo stampo |  | 1d | 2004-01-08 | 2004-01-08 | 66 | 57d | 0d | Merloni | 8h |
| 69 | 19.2 | Presentazione offerte con scheda stampo |  | 1w | 2004-01-09 | 2004-01-15 | 68 | 57d | 0d | Fornitori | 40h |
| 70 | 19.3 | Checkpoint1 | milestone | 0d | 2004-01-15 | 2004-01-15 | 69 | 57d | 0d | Team |  |
| 71 | 20 | **Fase2:Definizione dettaglie e selezione fornitori** |  | 6d | 2004-01-16 | 2004-01-23 |  | 57d |  |  | 88h |
| 72 | 20.1 | Analisi e selezione tra I lay-out proposti |  | 1w | 2004-01-16 | 2004-01-22 | 69, 70 | 57d | 0d | Merloni | 40h |
| 73 | 20.2 | Accettazione offerta |  | 1d | 2004-01-23 | 2004-01-23 | 72 | 57d | 0d | Merloni | 8h |
| 74 | 20.3 | Definizione completa delle specifiche del componente nei suoi dettagli |  | 1w | 2004-01-16 | 2004-01-22 | 68, 70 | 64d |  | Merloni | 40h |
| 75 | 20.4 | Checkpoint2 | milestone | 0d | 2004-01-23 | 2004-01-23 | 70, 73 | 57d | 0d | Team |  |
| 76 | 21 | **Fase4: Progettazione** |  | 25d | 2004-01-26 | 2004-02-27 |  | 57d |  |  | 280h |
| 77 | 21.1 | Definizione soluzioni definitive e dimensionamenti |  | 2w | 2004-01-26 | 2004-02-06 | 75 | 57d | 0d | Fornitore | 80h |
| 78 | 21.2 | Approvigionamenti materiali |  | 2w | 2004-02-09 | 2004-02-20 | 77 | 5d |  | Merloni | 80h |
| 79 | 21.3 | Progettazione Stampi |  | 3w | 2004-02-09 | 2004-02-27 | 77 | 57d | 0d | Fornitore | 120h |
| 80 | 21.4 | Checkpoint 4 | milestone | 0d | 2004-02-27 | 2004-02-27 | 78, 79 | 38d |  | Team |  |

| ID | WBS | Task | Type | Duration | Start | Finish | Predecessors | Total slack | Free slack | Resources | Work |
| --- | --- | --- | --- | --- | --- | --- | --- | --- | --- | --- | --- |
| 81 | 22 | **Fase5:Testing** |  | 15d | 2004-03-01 | 2004-03-19 |  | 80d |  |  | 200h |
| 82 | 22.1 | Valutazione dell'opportunità di Analisi Sperimentali anche a mezzo di prototipi |  | 1w | 2004-03-01 | 2004-03-05 | 79 | 23d | 0d | Merloni | 40h |
| 83 | 22.2 | Realizzazioni prototip e analisi |  | 10d | 2004-03-08 | 2004-03-19 | 82 | 23d |  | Fornitore; Merloni | 160h |
| 84 | 22.3 | checkpoint5 | milestone | 0d | 2004-03-05 | 2004-03-05 | 82 | 33d |  | Team |  |
| 85 | 23 | **Fase6:Costruzione** |  | 21d | 2004-03-01 | 2004-03-29 |  | 57d |  |  | 168h |
| 86 | 23.1 | Costruzione stampi |  | 4w | 2004-03-01 | 2004-03-26 | 78, 79 | 57d | 0d | Fornitore | 160h |
| 87 | 23.2 | Prima campionatura |  | 1d | 2004-03-29 | 2004-03-29 | 86 | 57d | 0d | Fornitore | 8h |
| 88 | 23.3 | Checkpoint6 | milestone | 0d | 2004-03-29 | 2004-03-29 | 87 | 57d | 0d | Team |  |
| 89 | 24 | **Fase7: Benestare** |  | 17d | 2004-03-30 | 2004-04-21 |  | 57d |  |  | 216h |
| 90 | 24.1 | Verifica dimensionale e funzionale |  | 1w | 2004-03-30 | 2004-04-05 | 88 | 57d | 0d | Merloni; Fornitore | 80h |
| 91 | 24.2 | Prima messa a punto degli stampi |  | 1w | 2004-04-06 | 2004-04-12 | 90 | 57d | 0d | Fornitore; Merloni | 80h |
| 92 | 24.3 | Nuovo collaudo |  | 1d | 2004-04-13 | 2004-04-13 | 91 | 57d | 0d | Fornitore | 8h |
| 93 | 24.4 | Rilievo non conformità |  | 1w | 2004-04-14 | 2004-04-20 | 92 | 57d | 0d | Merloni | 40h |
| 94 | 24.5 | Benestare dimensionale e funzionale |  | 1d | 2004-04-21 | 2004-04-21 | 93 | 57d | 0d | Merloni | 8h |
| 95 | 24.6 | Checkpoint7 | milestone | 0d | 2004-04-21 | 2004-04-21 | 94 | 57d |  |  |  |
