# Varie

Schedule from MS Project, 2004-01-01 to 2004-06-07.
Merloni Elettrodomestici

## Calendars

- Standard: Mon-Fri 08:00-12:00, 13:00-17:00; Sat-Sun off.

## Resources

| Resource | Cost per use |
| --- | --- |
| Fornitore | 300 |
| Merloni |  |
| Team |  |
| Fornitori |  |
| R&D |  |
| EDT |  |

## Schedule

| ID | WBS | Task | Type | Duration | Start | Finish | Predecessors | Total slack | Free slack | Resources | Work |
| --- | --- | --- | --- | --- | --- | --- | --- | --- | --- | --- | --- |
| 1 | 1 | Contrappesi Vibro-colati |  | 1d? | 2004-01-01 | 2004-01-01 |  | 104d |  |  |  |
| 2 | 2 | **Fase1: Apertura contatti con I Fornitori** |  | 5d | 2004-01-01 | 2004-01-07 |  | 15d |  |  | 40h |
| 3 | 2.1 | Presentazione disegno e richiesta offerte | milestone | 0d | 2004-01-01 | 2004-01-01 |  | 7d | 0d | Merloni |  |
| 4 | 2.2 | Presentazione offerte |  | 1w | 2004-01-01 | 2004-01-07 | 3 | 7d | 0d | Fornitori | 40h |
| 5 | 2.3 | Checkpoint1 | milestone | 0d | 2004-01-07 | 2004-01-07 | 4 | 7d | 0d | Team |  |
| 6 | 3 | **Fase2: Definizioni dettagli e selezione Fornitore** |  | 10d | 2004-01-08 | 2004-01-21 |  | 15d |  |  | 120h |
| 7 | 3.1 | Definizione piano di lavoro |  | 1w | 2004-01-08 | 2004-01-14 | 5 | 95d |  | Merloni | 40h |
| 8 | 3.2 | Analisi offerte |  | 2w | 2004-01-08 | 2004-01-21 | 4, 5 | 7d | 0d | Merloni | 80h |
| 9 | 3.3 | Accettazione offerta | milestone | 0d | 2004-01-21 | 2004-01-21 | 8 | 7d | 0d | Merloni |  |
| 10 | 3.4 | Checkpoint2 | milestone | 0d | 2004-01-21 | 2004-01-21 | 9 | 7d | 0d | Team |  |
| 11 | 4 | **Fase3: Consegna disegni** |  | 5d | 2004-01-22 | 2004-01-28 |  | 15d |  |  | 40h |
| 12 | 4.1 | Consegna Disegni e specifiche tecniche |  | 1w | 2004-01-22 | 2004-01-28 | 10 | 7d | 0d | Merloni | 40h |
| 13 | 4.2 | Checkpoint 3 | milestone | 0d | 2004-01-28 | 2004-01-28 | 12 | 7d | 0d | Team |  |
| 14 | 5 | Approvigionamenti materiali |  | 1w | 2004-01-22 | 2004-01-28 | 10 | 85d |  | Fornitore | 40h |
| 15 | 6 | **Fase4:Proggetazione e Costruzione** |  | 61d | 2004-01-29 | 2004-04-22 |  | 15d |  |  | 488h |
| 16 | 6.1 | Realizzazione stampo madre |  | 3mo | 2004-01-29 | 2004-04-21 | 13 | 7d | 0d | Fornitore | 480h |
| 17 | 6.2 | Prima campionatura |  | 1d | 2004-04-22 | 2004-04-22 | 16 | 7d | 0d | Fornitore | 8h |
| 18 | 6.3 | Checkpoint6 | milestone | 0d | 2004-04-22 | 2004-04-22 | 17 | 24d |  | Team |  |
| 19 | 7 | **Fase6: Benestare** |  | 17d | 2004-04-23 | 2004-05-17 |  | 15d |  |  | 136h |
| 20 | 7.1 | Verifica dimensionale, funzionale e di montaggio |  | 1w | 2004-04-23 | 2004-04-29 | 17 | 7d | 0d | Fornitore | 40h |
| 21 | 7.2 | Messa a punto stampo |  | 1w | 2004-04-30 | 2004-05-06 | 20 | 7d | 0d | Fornitore | 40h |
| 22 | 7.3 | Benestare dimensionale e funzionale |  | 1w | 2004-05-07 | 2004-05-13 | 21 | 7d | 0d | Merloni | 40h |
| 23 | 7.4 | Produzione gusci |  | 2d | 2004-05-14 | 2004-05-17 | 22 | 7d |  | Merloni | 16h |
| 25 | 8 | Polistirolo |  | 1d? | 2004-01-01 | 2004-01-01 |  | 104d |  |  |  |

| ID | WBS | Task | Type | Duration | Start | Finish | Predecessors | Total slack | Free slack | Resources | Work |
| --- | --- | --- | --- | --- | --- | --- | --- | --- | --- | --- | --- |
| 26 | 9 | **Fase1: Apertura contatti con I Fornitori** |  | 5d | 2004-01-01 | 2004-01-07 |  | 30d |  |  | 40h |
| 27 | 9.1 | Presentazione disegno e richiesta offerte | milestone | 0d | 2004-01-01 | 2004-01-01 |  | 65d | 0d | Merloni |  |
| 28 | 9.2 | Presentazione offerte |  | 1w | 2004-01-01 | 2004-01-07 | 27 | 65d | 0d | Fornitori | 40h |
| 29 | 9.3 | Checkpoint1 | milestone | 0d | 2004-01-07 | 2004-01-07 | 28 | 65d | 0d | Team |  |
| 30 | 10 | **Fase2: Definizioni dettagli e selezione Fornitore** |  | 10d | 2004-01-08 | 2004-01-21 |  | 30d |  |  | 120h |
| 31 | 10.1 | Definizione piano di lavoro |  | 1w | 2004-01-08 | 2004-01-14 | 29 | 95d |  | Merloni | 40h |
| 32 | 10.2 | Analisi offerte |  | 2w | 2004-01-08 | 2004-01-21 | 28, 29 | 65d | 0d | Merloni | 80h |
| 33 | 10.3 | Accettazione offerta | milestone | 0d | 2004-01-21 | 2004-01-21 | 32 | 65d | 0d | Merloni |  |
| 34 | 10.4 | Checkpoint2 | milestone | 0d | 2004-01-21 | 2004-01-21 | 29, 33 | 65d | 0d | Team |  |
| 35 | 11 | **Fase3: Codesign** |  | 25d | 2004-01-22 | 2004-02-25 |  | 73d |  |  | 264h |
| 36 | 11.1 | Consegna Ingombri e specifiche tecniche |  | 1w | 2004-01-22 | 2004-01-28 | 33, 34 | 65d | 0d | Merloni | 40h |
| 37 | 11.2 | Codesign |  | 8d | 2004-01-29 | 2004-02-09 | 36 | 65d | 0d | Fornitore; Merloni | 128h |
| 38 | 11.3 | Release al Codesign |  | 2d | 2004-02-10 | 2004-02-11 | 37 | 65d | 0d | Merloni | 16h |
| 39 | 11.4 | Svuluppo Disegni Imballaggio |  | 10d | 2004-02-12 | 2004-02-25 | 38 | 65d | 0d | Merloni | 80h |
| 40 | 11.5 | Checkpoint 3 | milestone | 0d | 2004-02-25 | 2004-02-25 | 39 | 65d |  | Team |  |
| 41 | 12 | Approvigionamenti materiali |  | 1w | 2004-01-22 | 2004-01-28 | 33, 34 | 85d |  | Fornitore | 40h |
| 42 | 13 | **Fase4:Proggetazione e Costruzione** |  | 41d | 2004-01-29 | 2004-03-25 |  | 30d |  |  | 328h |
| 43 | 13.1 | Realizzazione stampi |  | 2mo | 2004-01-29 | 2004-03-24 | 41 | 30d | 0d | Fornitore | 320h |
| 44 | 13.2 | Prima campionatura |  | 1d | 2004-03-25 | 2004-03-25 | 43 | 30d | 0d | Fornitore | 8h |
| 45 | 13.3 | Checkpoint6 | milestone | 0d | 2004-03-25 | 2004-03-25 | 44 | 52d |  | Team |  |
| 46 | 14 | **Fase6: Benestare** |  | 22d | 2004-03-26 | 2004-04-26 |  | 30d |  |  | 256h |
| 47 | 14.1 | Verifica dimensionale, funzionale e di montaggio |  | 1w | 2004-03-26 | 2004-04-01 | 44 | 30d | 0d | Fornitore | 40h |
| 48 | 14.2 | Messa a punto |  | 2w | 2004-04-02 | 2004-04-15 | 47 | 30d | 0d | Fornitore | 80h |
| 49 | 14.3 | Omologazione |  | 2w | 2004-04-02 | 2004-04-15 | 47 | 30d | 0d | Merloni | 80h |
| 50 | 14.4 | Nuovo collaudo |  | 1d | 2004-04-16 | 2004-04-16 | 48, 49 | 30d | 0d | Fornitore | 8h |
| 51 | 14.5 | Verifica dimensionale e funzionale |  | 1w | 2004-04-19 | 2004-04-23 | 50 | 30d | 0d | Merloni | 40h |
| 52 | 14.6 | Benestare dimensionale e funzionale |  | 1d | 2004-04-26 | 2004-04-26 | 51 | 30d |  | Merloni | 8h |
| 54 | 15 | Elettronica |  | 1d? | 2004-01-01 | 2004-01-01 |  | 104d |  |  |  |

| ID | WBS | Task | Type | Duration | Start | Finish | Predecessors | Total slack | Free slack | Resources | Work |
| --- | --- | --- | --- | --- | --- | --- | --- | --- | --- | --- | --- |
| 55 | 16 | **Fase1:Preliminare** |  | 0d | 2004-01-01 | 2004-01-01 |  | 8d |  |  |  |
| 56 | 16.1 | Release al DT | milestone | 0d | 2004-01-01 | 2004-01-01 |  | 8d | 0d | Merloni |  |
| 57 | 16.2 | Release al DE | milestone | 0d | 2004-01-01 | 2004-01-01 |  | 8d | 0d | Merloni |  |
| 58 | 17 | **Fase2: Definizione specifiche** |  | 25d | 2004-01-01 | 2004-02-04 |  | 8d |  |  | 200h |
| 59 | 17.1 | Definizione specifiche dettagliate meccaniche dell'elettronica |  | 5w | 2004-01-01 | 2004-02-04 | 56, 57 | 8d | 0d | R&D | 200h |
| 60 | 17.2 | Checkpoint2 | milestone | 0d | 2004-02-04 | 2004-02-04 | 59 | 8d | 0d | Team |  |
| 61 | 18 | **Fase3: Sviluppo Hw e SW 1** |  | 30d | 2004-02-05 | 2004-03-17 |  | 8d |  |  | 360h |
| 62 | 18.1 | Sviluppo LP1 |  | 6w | 2004-02-05 | 2004-03-17 | 60 | 8d | 0d | EDT | 240h |
| 63 | 18.2 | Sviluppo SWalfa |  | 3w | 2004-02-05 | 2004-02-25 | 60 | 8d | 0d | EDT | 120h |
| 64 | 18.3 | checkpoint3 | milestone | 0d | 2004-02-25 | 2004-02-25 | 63 | 65d |  | Team |  |
| 65 | 19 | **Fase4: Prove in macchina** |  | 65d | 2004-02-26 | 2004-05-26 |  | 8d |  |  | 840h |
| 66 | 19.1 | Debug Swalfa |  | 6w | 2004-02-26 | 2004-04-07 | 63 | 35d |  | R&D | 240h |
| 67 | 19.2 | Prove di qualificazione in macchina LP1 |  | 8w | 2004-03-18 | 2004-05-12 | 62 | 10d |  | R&D | 320h |
| 68 | 19.3 | Debug Swbeta |  | 5w | 2004-04-08 | 2004-05-12 | 74 | 8d | 0d | R&D | 200h |
| 69 | 19.4 | Release HW |  | 2w | 2004-05-13 | 2004-05-26 | 68, 73 | 8d | 0d | R&D | 80h |
| 70 | 19.5 | checkpoint4 | milestone | 0d | 2004-05-26 | 2004-05-26 | 69 | 8d | 0d | Team |  |
| 71 | 20 | **Fase5: Sviluppo HW e SW 2** |  | 65d | 2004-02-26 | 2004-05-26 |  | 8d |  |  | 640h |
| 72 | 20.1 | Debug LP1 |  | 2w | 2004-03-18 | 2004-03-31 | 62 | 8d | 0d | EDT | 80h |
| 73 | 20.2 | Sviluppo PP1 |  | 6w | 2004-04-01 | 2004-05-12 | 72 | 8d | 0d | EDT | 240h |
| 74 | 20.3 | Sviluppo Swbeta |  | 6w | 2004-02-26 | 2004-04-07 | 63 | 8d | 0d | EDT | 240h |
| 75 | 20.4 | Debug PP1 |  | 2w | 2004-05-13 | 2004-05-26 | 73 | 8d | 0d | EDT | 80h |
| 76 | 20.5 | Checkpoint 5 | milestone | 0d | 2004-05-26 | 2004-05-26 | 75 | 8d | 0d | Team |  |
| 77 | 21 | Consegna elettronica per HT | milestone | 0d | 2004-05-26 | 2004-05-26 | 70, 76 | 8d |  |  |  |
| 79 | 22 | Vetro oblò |  | 1d? | 2004-01-01 | 2004-01-01 |  | 112d |  |  |  |

| ID | WBS | Task | Type | Duration | Start | Finish | Predecessors | Total slack | Free slack | Resources | Work |
| --- | --- | --- | --- | --- | --- | --- | --- | --- | --- | --- | --- |
| 80 | 23 | **Fase1: Apertura contatti con I Fornitori** |  | 5d | 2004-01-01 | 2004-01-07 |  | 0d |  |  | 40h |
| 81 | 23.1 | Presentazione disegno e richiesta offerte | milestone | 0d | 2004-01-01 | 2004-01-01 |  | 0d |  | Merloni |  |
| 82 | 23.2 | Presentazione offerte |  | 1w | 2004-01-01 | 2004-01-07 | 81 | 0d |  | Fornitori | 40h |
| 83 | 23.3 | Checkpoint1 | milestone | 0d | 2004-01-07 | 2004-01-07 | 82 | 0d |  | Team |  |
| 84 | 24 | **Fase2: Definizioni dettagli e selezione Fornitore** |  | 10d | 2004-01-08 | 2004-01-21 |  | 0d |  |  | 120h |
| 85 | 24.1 | Definizione piano di lavoro |  | 1w | 2004-01-08 | 2004-01-14 | 83 | 103d |  | Merloni | 40h |
| 86 | 24.2 | Analisi offerte |  | 2w | 2004-01-08 | 2004-01-21 | 82, 83 | 0d |  | Merloni | 80h |
| 87 | 24.3 | Accettazione offerta | milestone | 0d | 2004-01-21 | 2004-01-21 | 86 | 0d |  | Merloni |  |
| 88 | 24.4 | Checkpoint2 | milestone | 0d | 2004-01-21 | 2004-01-21 | 83, 87 | 0d |  | Team |  |
| 89 | 25 | **Fase3: Disegni** |  | 5d | 2004-01-22 | 2004-01-28 |  | 0d |  |  | 40h |
| 90 | 25.1 | Consegna Disegni |  | 1w | 2004-01-22 | 2004-01-28 | 87, 88 | 0d |  | Merloni | 40h |
| 91 | 25.2 | Checkpoint 3 | milestone | 0d | 2004-01-28 | 2004-01-28 | 90 | 0d |  | Team |  |
| 92 | 26 | Approvigionamenti materiali |  | 2w | 2004-01-22 | 2004-02-04 | 87, 88 | 40d | 10d | Fornitore | 80h |
| 93 | 27 | **Fase4: Progettazione** |  | 30d | 2004-01-29 | 2004-03-10 |  | 0d |  |  | 360h |
| 94 | 27.1 | Progettazione di massima |  | 3w | 2004-01-29 | 2004-02-18 | 91 | 30d | 0d | Fornitore | 120h |
| 95 | 27.2 | Progettazione dettagli |  | 6w | 2004-01-29 | 2004-03-10 | 91 | 0d |  | Fornitore | 240h |
| 96 | 27.3 | checkpoint5 | milestone | 0d | 2004-03-10 | 2004-03-10 | 95 | 63d |  | Team |  |
| 97 | 28 | **Fase5: Costruzione** |  | 51d | 2004-02-19 | 2004-04-29 |  | 15d |  |  | 368h |
| 98 | 28.1 | Lavorazione portastampi |  | 2w | 2004-02-19 | 2004-03-03 | 92, 94 | 30d |  | Fornitore | 80h |
| 99 | 28.2 | Lavorazione parti stampanti |  | 5w | 2004-03-11 | 2004-04-14 | 95 | 0d |  | Fornitore | 200h |
| 100 | 28.3 | Assemblaggio Stampi |  | 2w | 2004-04-15 | 2004-04-28 | 98, 99 | 0d |  | Fornitore | 80h |
| 101 | 28.4 | Prima campionatura con stampo 9 impronte |  | 1d | 2004-04-29 | 2004-04-29 | 100 | 0d |  | Fornitore | 8h |
| 102 | 28.5 | Checkpoint6 | milestone | 0d | 2004-04-29 | 2004-04-29 | 101 | 27d |  | Team |  |
| 103 | 29 | **Fase6: Benestare** |  | 27d | 2004-04-30 | 2004-06-07 |  | 0d |  |  | 376h |
| 104 | 29.1 | Verifica dimensionale, funzionale e di montaggio |  | 1w | 2004-04-30 | 2004-05-06 | 101 | 0d |  | Fornitore | 40h |
| 105 | 29.2 | Messa a punto |  | 3w | 2004-05-07 | 2004-05-27 | 104 | 0d |  | Fornitore | 120h |
| 106 | 29.3 | Trattamenti |  | 3w | 2004-05-07 | 2004-05-27 | 104 | 0d |  | Fornitore | 120h |
| 107 | 29.4 | Nuovo collaudo |  | 1d | 2004-05-28 | 2004-05-28 | 105, 106 | 0d |  | Fornitore | 8h |
| 108 | 29.5 | Verifica dimensionale e funzionale |  | 1w | 2004-05-31 | 2004-06-04 | 107 | 0d |  | Merloni | 40h |
| 109 | 29.6 | Benestare dimensionale e funzionale |  | 1d | 2004-06-07 | 2004-06-07 | 108 | 0d |  | Merloni | 8h |
| 110 | 29.7 | Completamento stampo |  | 1w | 2004-05-31 | 2004-06-04 | 107 | 1d |  | Fornitore | 40h |
