# Linee

Schedule from MS Project, 2004-01-01 to 2005-08-31.
Merloni Elettrodomestici

## Calendars

- Standard: Mon-Fri 08:00-12:00, 13:00-17:00; Sat-Sun off.

## Resources

| Resource |
| --- |
| Fornitore |
| Merloni |
| Team |
| Fornitori |
| f |

## Schedule

| ID | WBS | Task | Type | Duration | Start | Finish | Predecessors | Total slack | Free slack | Resources | Work |
| --- | --- | --- | --- | --- | --- | --- | --- | --- | --- | --- | --- |
| 1 | 1 | Linea Flessibile Vasca e Cesto |  | 1d? | 2004-01-01 | 2004-01-01 |  | 434d |  |  |  |
| 2 | 2 | **Fase1: Apertura contatti con I Fornitori** |  | 20d | 2004-01-01 | 2004-01-28 |  | 175d |  |  | 160h |
| 3 | 2.1 | Presentazione disegno e richiesta offerte | milestone | 0d | 2004-01-01 | 2004-01-01 |  | 175d | 0d | Merloni |  |
| 4 | 2.2 | Presentazione offerte |  | 4w | 2004-01-01 | 2004-01-28 | 3 | 175d | 0d | Fornitori | 160h |
| 5 | 2.3 | Checkpoint1 | milestone | 0d | 2004-01-28 | 2004-01-28 | 4 | 175d | 0d | Team |  |
| 6 | 3 | **Fase2: Definizioni dettagli e selezione Fornitore** |  | 10d | 2004-01-29 | 2004-02-11 |  | 175d |  |  | 160h |
| 7 | 3.1 | Definizione piano di lavoro |  | 2w | 2004-01-29 | 2004-02-11 | 5 | 405d |  | Merloni | 80h |
| 8 | 3.2 | Analisi offerte |  | 2w | 2004-01-29 | 2004-02-11 | 4, 5 | 175d | 0d | Merloni | 80h |
| 9 | 3.3 | Accettazione offerta | milestone | 0d | 2004-02-11 | 2004-02-11 | 8 | 175d | 0d | Merloni |  |
| 10 | 3.4 | Checkpoint2 | milestone | 0d | 2004-02-11 | 2004-02-11 | 9, 5 | 175d | 0d | Team |  |
| 11 | 4 | **Fase3: Progettazione in Coodesign** |  | 85d | 2004-02-12 | 2004-06-09 |  | 320d |  |  | 680h |
| 12 | 4.1 | Progettazione |  | 17w | 2004-02-12 | 2004-06-09 | 10 | 320d | 0d | Fornitore | 680h |
| 13 | 4.2 | checkpoint5 | milestone | 0d | 2004-06-09 | 2004-06-09 | 12 | 320d |  | Team |  |
| 14 | 5 | **Fase4: Costruzione** |  | 155d | 2004-03-11 | 2004-10-13 |  | 175d |  |  | 2080h |
| 15 | 5.1 | Lavorazione |  | 25w | 2004-03-11 | 2004-09-01 | 10SS+4w | 175d | 0d | Fornitore | 1000h |
| 16 | 5.2 | Assemblaggio linea e utility |  | 26w | 2004-04-08 | 2004-10-06 | 15SS+4w | 175d | 0d | Fornitore | 1040h |
| 17 | 5.3 | Prima campionatura |  | 1w | 2004-10-07 | 2004-10-13 | 16 | 175d | 0d | Fornitore | 40h |
| 18 | 5.4 | Checkpoint6 | milestone | 0d | 2004-10-13 | 2004-10-13 | 17 | 230d |  | Team |  |
| 19 | 6 | **Fase5: Benestare** |  | 55d | 2004-10-14 | 2004-12-29 |  | 175d |  |  | 720h |
| 20 | 6.1 | Verifica dimensionale, funzionale e di montaggio |  | 1w | 2004-10-14 | 2004-10-20 | 17 | 175d | 0d | Fornitore | 40h |
| 21 | 6.2 | Messa a punto |  | 4w | 2004-10-21 | 2004-11-17 | 20 | 175d | 0d | Fornitore | 160h |
| 22 | 6.3 | Trattamenti |  | 4w | 2004-10-21 | 2004-11-17 | 20 | 175d | 0d | Fornitore | 160h |
| 23 | 6.4 | Nuovo collaudo |  | 1w | 2004-11-18 | 2004-11-24 | 21, 22 | 175d | 0d | Fornitore | 40h |
| 24 | 6.5 | Verifica dimensionale e funzionale |  | 2w | 2004-11-25 | 2004-12-08 | 23 | 175d | 0d | Merloni | 80h |
| 25 | 6.6 | Benestare dimensionale e funzionale |  | 3w | 2004-12-09 | 2004-12-29 | 24 | 175d |  | Merloni | 120h |
| 26 | 6.7 | Completamento stampo |  | 3w | 2004-11-25 | 2004-12-15 | 23 | 185d |  | Fornitore | 120h |
| 28 | 7 | Linea Flessibile Mobile |  | 1d? | 2004-01-01 | 2004-01-01 |  | 434d |  |  |  |

| ID | WBS | Task | Type | Duration | Start | Finish | Predecessors | Total slack | Resources | Work |
| --- | --- | --- | --- | --- | --- | --- | --- | --- | --- | --- |
| 29 | 8 | **Fase1: Apertura contatti con I Fornitori** |  | 20d | 2004-01-01 | 2004-01-28 |  | 0d |  | 160h |
| 30 | 8.1 | Presentazione disegno e richiesta offerte | milestone | 0d | 2004-01-01 | 2004-01-01 |  | 0d | Merloni |  |
| 31 | 8.2 | Presentazione offerte |  | 4w | 2004-01-01 | 2004-01-28 | 30 | 0d | Fornitori | 160h |
| 32 | 8.3 | Checkpoint1 | milestone | 0d | 2004-01-28 | 2004-01-28 | 31 | 0d | Team |  |
| 33 | 9 | **Fase2: Definizioni dettagli e selezione Fornitore** |  | 10d | 2004-01-29 | 2004-02-11 |  | 0d |  | 160h |
| 34 | 9.1 | Definizione piano di lavoro |  | 2w | 2004-01-29 | 2004-02-11 | 32 | 405d | Merloni | 80h |
| 35 | 9.2 | Analisi offerte |  | 2w | 2004-01-29 | 2004-02-11 | 31, 32 | 0d | Merloni | 80h |
| 36 | 9.3 | Accettazione offerta | milestone | 0d | 2004-02-11 | 2004-02-11 | 35 | 0d | Merloni |  |
| 37 | 9.4 | Checkpoint2 | milestone | 0d | 2004-02-11 | 2004-02-11 | 32, 36 | 0d | Team |  |
| 38 | 10 | **Fase3: Progettazione in Coodesign** |  | 200d | 2004-01-01 | 2004-10-06 |  | 30d |  | 1360h |
| 39 | 10.1 | Progettazione |  | 34w | 2004-02-12 | 2004-10-06 | 37 | 0d | Fornitore | 1360h |
| 40 | 10.2 | checkpoint5 | milestone | 0d | 2004-01-01 | 2004-01-01 |  | 435d | Team |  |
| 41 | 11 | **Fase4: Costruzione** |  | 260d | 2004-04-08 | 2005-04-06 |  | 0d |  | 3120h |
| 42 | 11.1 | Lavorazione |  | 34w | 2004-04-08 | 2004-12-01 | 39SS+8w | 0d | Fornitore | 1360h |
| 43 | 11.2 | Assemblaggio linea e utility |  | 43w | 2004-06-03 | 2005-03-30 | 42SS+8w | 0d | Fornitore | 1720h |
| 44 | 11.3 | Prima campionatura |  | 1w | 2005-03-31 | 2005-04-06 | 43 | 0d | Fornitore | 40h |
| 45 | 11.4 | Checkpoint6 | milestone | 0d | 2005-04-06 | 2005-04-06 | 44 | 105d | Team |  |
| 46 | 12 | **Fase5: Benestare** |  | 105d | 2005-04-07 | 2005-08-31 |  | 0d |  | 1480h |
| 47 | 12.1 | Verifica dimensionale, funzionale e di montaggio |  | 2w | 2005-04-07 | 2005-04-20 | 44 | 0d | Fornitore | 80h |
| 48 | 12.2 | Messa a punto |  | 12w | 2005-04-21 | 2005-07-13 | 47 | 0d | Fornitore | 480h |
| 49 | 12.3 | Trattamenti |  | 12w | 2005-04-21 | 2005-07-13 | 47 | 0d | Fornitore | 480h |
| 50 | 12.4 | Nuovo collaudo |  | 2w | 2005-07-14 | 2005-07-27 | 48, 49 | 0d | Fornitore | 80h |
| 51 | 12.5 | Verifica dimensionale e funzionale |  | 2w | 2005-07-28 | 2005-08-10 | 50 | 0d | Merloni | 80h |
| 52 | 12.6 | Benestare dimensionale e funzionale |  | 3w | 2005-08-11 | 2005-08-31 | 51 | 0d | Merloni | 120h |
| 53 | 12.7 | Completamento stampo |  | 4w | 2005-07-28 | 2005-08-24 | 50 | 5d | Fornitore | 160h |
